# 民宿開發案 PROJECT PLAN

Schedule from MS Project, 2010-01-01 to 2010-08-17, costs in $.
ITRI

## Calendars

- 標準: Mon-Fri 08:00-12:00, 13:00-17:00; Sat-Sun off.

## Schedule

| ID | WBS | Task | Type | Duration | Start | Finish | Predecessors | Baseline start | Baseline finish | Baseline duration | Total slack | Free slack | Work | Cost |
| --- | --- | --- | --- | --- | --- | --- | --- | --- | --- | --- | --- | --- | --- | --- |
| 1 | 1 | **民宿興建時程計畫** |  | 163d | 2010-01-01 | 2010-08-17 |  |  |  |  | 0d |  | 30h | 12,827,000 |
| 2 | 1.1 | **民宿地點評估計畫** |  | 50d | 2010-01-01 | 2010-03-11 |  |  |  |  | 0d |  |  | 7,000,000 |
| 3 | 1.1.1 | **地點選定計劃** |  | 35d | 2010-01-01 | 2010-02-18 |  |  |  |  | 0d |  |  |  |
| 4 | 1.1.1.1 | **縣市地點評估** |  | 15d | 2010-01-01 | 2010-01-21 |  |  |  |  | 0d |  |  |  |
| 5 | 1.1.1.1.1 | **地點/特色優劣分析** |  | 15d | 2010-01-01 | 2010-01-21 |  |  |  |  | 0d |  |  |  |
| 6 | 1.1.1.1.1.1 | 民宿地點特色分享 |  | 15d | 2010-01-01 | 2010-01-21 |  |  |  |  | 0d |  |  |  |
| 7 | 1.1.1.1.1.2 | 縣市政府政策 |  | 5d | 2010-01-01 | 2010-01-07 | 6SS |  |  |  | 9d |  |  |  |
| 8 | 1.1.1.1.2 | 參與計劃人表決 |  | 1d | 2010-01-21 | 2010-01-21 | 6FF, 7 |  |  |  | 0d |  |  |  |
| 9 | 1.1.1.2 | **鄉鎮地點評估** |  | 20d | 2010-01-22 | 2010-02-18 | 4 |  |  |  | 0d |  |  |  |
| 10 | 1.1.1.2.1 | 交通 |  | 20d | 2010-01-22 | 2010-02-18 |  |  |  |  | 0d |  |  |  |
| 11 | 1.1.1.2.2 | 風景區 |  | 20d | 2010-01-22 | 2010-02-18 |  |  |  |  | 0d |  |  |  |
| 12 | 1.1.1.2.3 | 地價 |  | 20d | 2010-01-22 | 2010-02-18 |  |  |  |  | 0d |  |  |  |
| 13 | 1.1.1.2.4 | 進入障礙 |  | 20d | 2010-01-22 | 2010-02-18 |  |  |  |  | 0d |  |  |  |
| 14 | 1.1.2 | **土地取得計劃** |  | 15d | 2010-02-19 | 2010-03-11 |  |  |  |  | 0d |  |  | 7,000,000 |
| 15 | 1.1.2.1 | **相關法規** |  | 5d | 2010-02-19 | 2010-02-25 | 9 |  |  |  | 0d |  |  |  |
| 16 | 1.1.2.1.1 | 民宿管理法 |  | 5d | 2010-02-19 | 2010-02-25 |  |  |  |  | 0d |  |  |  |
| 17 | 1.1.2.2 | **土地品質考量** |  | 10d | 2010-02-26 | 2010-03-11 | 4, 9, 15 |  |  |  | 0d |  |  |  |
| 18 | 1.1.2.2.1 | 土地面積 |  | 10d | 2010-02-26 | 2010-03-11 |  |  |  |  | 0d |  |  |  |
| 19 | 1.1.2.2.2 | 土地方位 |  | 10d | 2010-02-26 | 2010-03-11 |  |  |  |  | 0d |  |  |  |
| 20 | 1.1.2.3 | **土地議價比價** |  | 5d | 2010-02-26 | 2010-03-04 | 15, 17SS |  |  |  | 1d | 0d |  | 7,000,000 |
| 21 | 1.1.2.3.1 | 參與人表決 |  | 5d | 2010-02-26 | 2010-03-04 |  |  |  |  | 1d | 0d |  |  |
| 22 | 1.1.2.4 | **購買土地** |  | 4d | 2010-03-05 | 2010-03-10 | 20 |  |  |  | 1d |  |  |  |
| 23 | 1.1.2.4.1 | 所有權狀 |  | 4d | 2010-03-05 | 2010-03-10 |  |  |  |  | 1d | 0d |  |  |
| 24 | 1.2 | **民宿資金、成本與預算管理** |  | 163d | 2010-01-01 | 2010-08-17 |  | 2004-08-02 | 2005-05-31 | 217d | 0d |  |  | 550,000 |
| 25 | 1.2.1 | **資金籌備** |  | 3d | 2010-01-01 | 2010-01-05 |  | 2004-08-02 | 2004-08-31 | 22d | 43d | 0d |  |  |
| 26 | 1.2.1.1 | **股東出資** |  | 3d | 2010-01-01 | 2010-01-05 |  | 2004-08-02 | 2004-08-05 | 4d | 43d |  |  |  |
| 27 | 1.2.1.1.1 | 資金到位 |  | 3d | 2010-01-01 | 2010-01-05 | 6SS | 2004-08-02 | 2004-08-04 | 3d | 43d | 0d |  |  |
| 28 | 1.2.1.1.2 | 帳戶統籌管理 | milestone | 1d | 2010-01-05 | 2010-01-05 | 27FF | 2004-08-05 | 2004-08-05 | 1d | 43d | 0d |  |  |

| ID | WBS | Task | Type | Duration | Start | Finish | Predecessors | Baseline start | Baseline finish | Baseline duration | Total slack | Free slack |
| --- | --- | --- | --- | --- | --- | --- | --- | --- | --- | --- | --- | --- |
| 29 | 1.2.2 | **建設階段資金運用** |  | 130d | 2010-02-15 | 2010-08-13 |  | 2004-08-02 | 2005-02-28 | 151d | 2d |  |
| 30 | 1.2.2.1 | **土地** |  | 14d | 2010-02-15 | 2010-03-04 |  | 2004-08-02 | 2004-10-08 | 50d | 15d |  |
| 31 | 1.2.2.1.1 | 議價 |  | 14d | 2010-02-15 | 2010-03-04 | 28, 21FF | 2004-09-01 | 2004-09-20 | 14d | 15d | 0d |
| 32 | 1.2.2.1.2 | 簽約及付款 | milestone | 4d | 2010-03-01 | 2010-03-04 | 31FF | 2004-09-21 | 2004-09-24 | 4d | 15d |  |
| 33 | 1.2.2.2 | **建物** |  | 77d | 2010-03-26 | 2010-07-12 |  | 2004-09-27 | 2005-02-28 | 111d | 6d |  |
| 34 | 1.2.2.2.1 | 議價 |  | 1d | 2010-03-26 | 2010-03-26 | 85, 86, 87 | 2004-10-21 | 2004-10-29 | 7d | 6d | 0d |
| 35 | 1.2.2.2.2 | 簽約 |  | 1d | 2010-03-26 | 2010-03-26 | 34FF |  |  |  | 6d |  |
| 36 | 1.2.2.2.3 | 驗收及付款 | milestone | 1d | 2010-07-12 | 2010-07-12 | 115 |  |  |  | 26d |  |
| 37 | 1.2.2.3 | **裝潢及室內設計** |  | 97d | 2010-03-26 | 2010-08-09 |  | 2005-01-03 | 2005-02-28 | 41d | 0d |  |
| 38 | 1.2.2.3.1 | 議價 |  | 1d | 2010-03-26 | 2010-03-26 | 90 | 2004-10-21 | 2004-10-29 | 7d | 75d | 0d |
| 39 | 1.2.2.3.2 | 簽約 |  | 1d | 2010-03-26 | 2010-03-26 | 38FF |  |  |  | 75d |  |
| 40 | 1.2.2.3.3 | 驗收及付款 | milestone | 1d | 2010-08-09 | 2010-08-09 | 127 | 2005-01-03 | 2005-02-28 | 41d | 0d |  |
| 41 | 1.2.2.4 | **景觀工程** |  | 87d | 2010-03-26 | 2010-07-26 |  | 2005-01-03 | 2005-02-28 | 41d | 16d |  |
| 42 | 1.2.2.4.1 | 議價 |  | 1d | 2010-03-26 | 2010-03-26 | 88 | 2004-10-21 | 2004-10-29 | 7d | 82d | 0d |
| 43 | 1.2.2.4.2 | 簽約 |  | 1d | 2010-03-26 | 2010-03-26 | 42FF |  |  |  | 82d | 75d |
| 44 | 1.2.2.4.3 | 驗收及付款 | milestone | 1d | 2010-07-26 | 2010-07-26 | 130 | 2005-01-03 | 2005-02-28 | 41d | 16d |  |
| 45 | 1.2.2.5 | **保全工程** |  | 74d | 2010-03-26 | 2010-07-07 |  | 2005-01-03 | 2005-02-28 | 41d | 29d |  |
| 46 | 1.2.2.5.1 | 議價 |  | 1d | 2010-03-26 | 2010-03-26 | 89 | 2004-10-21 | 2004-10-29 | 7d | 68d | 0d |
| 47 | 1.2.2.5.2 | 簽約 |  | 1d | 2010-03-26 | 2010-03-26 | 46FF |  |  |  | 68d | 65d |
| 48 | 1.2.2.5.3 | 驗收及付款 | milestone | 1d | 2010-07-07 | 2010-07-07 | 119 | 2005-01-03 | 2005-02-28 | 41d | 29d |  |
| 49 | 1.2.2.6 | **資訊軟硬體工程** |  | 108d | 2010-03-17 | 2010-08-13 |  | 2005-01-03 | 2005-02-28 | 41d | 2d |  |
| 50 | 1.2.2.6.1 | 議價 |  | 1d | 2010-03-17 | 2010-03-17 | 147 | 2004-10-21 | 2004-10-29 | 7d | 109d | 0d |
| 51 | 1.2.2.6.2 | 簽約 |  | 1d | 2010-03-17 | 2010-03-17 | 50FF |  |  |  | 109d |  |
| 52 | 1.2.2.6.3 | 驗收及付款 | milestone | 1d | 2010-08-13 | 2010-08-13 | 155, 156, 157, 158 | 2005-01-03 | 2005-02-28 | 41d | 2d |  |

| ID | WBS | Task | Type | Duration | Start | Finish | Predecessors | Baseline start | Baseline finish | Baseline duration | Total slack | Free slack | Constraint | Cost |
| --- | --- | --- | --- | --- | --- | --- | --- | --- | --- | --- | --- | --- | --- | --- |
| 53 | 1.2.3 | **預算控管計畫** |  | 15d | 2010-01-06 | 2010-01-26 |  | 2004-10-01 | 2004-10-29 | 21d | 142d |  |  |  |
| 54 | 1.2.3.1 | **編製預估報表** |  | 8d | 2010-01-06 | 2010-01-15 | 25 | 2004-10-01 | 2004-10-20 | 14d | 142d | 0d |  |  |
| 55 | 1.2.3.1.1 | 損益表 |  | 6d | 2010-01-06 | 2010-01-13 |  | 2004-10-01 | 2004-10-08 | 6d | 144d | 2d |  |  |
| 56 | 1.2.3.1.2 | 現金流量表 |  | 6d | 2010-01-06 | 2010-01-13 |  | 2004-10-01 | 2004-10-08 | 6d | 144d | 2d |  |  |
| 57 | 1.2.3.1.3 | 損益兩平 |  | 6d | 2010-01-06 | 2010-01-13 |  | 2004-10-01 | 2004-10-08 | 6d | 144d | 2d |  |  |
| 58 | 1.2.3.1.4 | 資金回收計畫 |  | 8d | 2010-01-06 | 2010-01-15 | 55FF, 56FF, 57FF | 2004-10-11 | 2004-10-20 | 8d | 142d | 0d |  |  |
| 59 | 1.2.3.2 | **營運報表設計** |  | 7d | 2010-01-18 | 2010-01-26 | 54 | 2004-10-21 | 2004-10-29 | 7d | 145d |  |  |  |
| 60 | 1.2.3.2.1 | 營運月報表 |  | 7d | 2010-01-18 | 2010-01-26 |  | 2004-10-21 | 2004-10-29 | 7d | 145d |  |  |  |
| 61 | 1.2.3.2.2 | 分析性報表 |  | 7d | 2010-01-18 | 2010-01-26 |  | 2004-10-21 | 2004-10-29 | 7d | 145d |  |  |  |
| 62 | 1.2.3.2.3 | 現金流量 |  | 7d | 2010-01-18 | 2010-01-26 |  | 2004-10-21 | 2004-10-29 | 7d | 145d |  |  |  |
| 63 | 1.2.4 | **正式營運前** |  | 161d | 2010-01-05 | 2010-08-17 |  | 2004-08-02 | 2005-04-29 | 195d | 0d |  |  | 550,000 |
| 64 | 1.2.4.1 | **營業支出** |  | 161d | 2010-01-05 | 2010-08-17 |  | 2004-08-02 | 2005-04-29 | 195d | 0d |  |  | 450,000 |
| 65 | 1.2.4.1.1 | 日常什支 |  | 158d | 2010-01-05 | 2010-08-12 | 196FF | 2004-08-02 | 2005-04-29 | 195d | 3d |  | start no earlier than 2004-09-08 | 400,000 |
| 66 | 1.2.4.1.2 | 環境整理 |  | 6d | 2010-08-10 | 2010-08-17 | 37, 196FF | 2005-03-01 | 2005-04-29 | 44d | 0d |  | start no earlier than 2004-09-07 | 50,000 |
| 67 | 1.2.4.2 | **行銷活動支出** |  | 30d | 2010-07-02 | 2010-08-12 |  | 2005-03-01 | 2005-04-29 | 44d | 3d |  |  |  |
| 68 | 1.2.4.2.1 | 廣告 |  | 30d | 2010-07-02 | 2010-08-12 | 196FF | 2005-03-01 | 2005-04-29 | 44d | 3d |  | start no earlier than 2005-03-01 |  |
| 69 | 1.2.4.3 | **保險支出** |  | 23d | 2010-07-14 | 2010-08-13 |  | 2005-03-01 | 2005-03-31 | 23d | 2d |  |  | 100,000 |
| 70 | 1.2.4.3.1 | 辦理產物保險 | milestone | 23d | 2010-07-14 | 2010-08-13 | 83FF | 2005-03-01 | 2005-03-31 | 23d | 2d |  | start no earlier than 2005-03-01 | 100,000 |
| 71 | 1.2.5 | **營運管理計畫** |  | 18d | 2010-01-06 | 2010-01-29 | 28 | 2004-08-02 | 2005-05-31 | 217d | 142d |  |  |  |
| 72 | 1.2.5.1 | **收支** |  | 10d | 2010-01-06 | 2010-01-19 |  | 2004-08-02 | 2005-05-31 | 217d | 150d |  |  |  |
| 73 | 1.2.5.1.1 | 營收 |  | 10d | 2010-01-06 | 2010-01-19 |  | 2005-05-02 | 2005-05-31 | 22d | 150d |  | finish no earlier than 2005-04-13 |  |
| 74 | 1.2.5.1.2 | 費用 |  | 5d | 2010-01-06 | 2010-01-12 | 28 | 2004-08-02 | 2005-05-31 | 217d | 155d |  | finish no earlier than 2005-04-13 |  |
| 75 | 1.2.5.2 | **損益分析** |  | 6d | 2010-01-06 | 2010-01-13 |  | 2004-08-02 | 2005-05-31 | 217d | 154d |  |  |  |
| 76 | 1.2.5.2.1 | 變動成本 |  | 6d | 2010-01-06 | 2010-01-13 | 28 | 2004-08-02 | 2005-05-31 | 217d | 154d |  | finish no earlier than 2005-04-08 |  |
| 77 | 1.2.5.2.2 | 固定成本 |  | 6d | 2010-01-06 | 2010-01-13 | 28 | 2004-08-02 | 2005-05-31 | 217d | 154d |  | finish no earlier than 2005-04-08 |  |

| ID | WBS | Task | Duration | Start | Finish | Predecessors | Baseline start | Baseline finish | Baseline duration | Total slack | Constraint | Cost |
| --- | --- | --- | --- | --- | --- | --- | --- | --- | --- | --- | --- | --- |
| 78 | 1.2.5.3 | **營運評估計畫** | 10d | 2010-01-18 | 2010-01-29 | 58 | 2005-01-03 | 2005-05-31 | 107d | 142d |  |  |
| 79 | 1.2.5.3.1 | 訂價政策 | 10d | 2010-01-18 | 2010-01-29 |  | 2005-03-01 | 2005-05-31 | 66d | 142d | finish no earlier than 2005-04-13 |  |
| 80 | 1.2.5.3.2 | 附加價值 | 10d | 2010-01-18 | 2010-01-29 |  | 2005-04-01 | 2005-05-31 | 43d | 142d | finish no earlier than 2005-04-13 |  |
| 81 | 1.2.5.3.3 | Cost down計畫 | 10d | 2010-01-18 | 2010-01-29 |  | 2005-01-03 | 2005-05-31 | 107d | 142d | finish no earlier than 2005-04-13 |  |
| 82 | 1.2.5.3.4 | 再投資計畫 | 10d | 2010-01-18 | 2010-01-29 |  | 2005-05-23 | 2005-05-31 | 7d | 142d | finish no earlier than 2005-04-13 |  |
| 83 | 1.3 | **建構民宿建物** | 111d | 2010-03-12 | 2010-08-13 |  |  |  |  | 0d |  | 4,724,000 |
| 84 | 1.3.1 | **建築藍圖** | 10d | 2010-03-12 | 2010-03-25 | 14 |  |  |  | 0d |  | 95,000 |
| 85 | 1.3.1.1 | 主體建物藍圖 | 10d | 2010-03-12 | 2010-03-25 |  |  |  |  | 0d |  | 60,000 |
| 86 | 1.3.1.2 | 水電設計圖 | 10d | 2010-03-12 | 2010-03-25 | 85FF |  |  |  | 0d |  | 10,000 |
| 87 | 1.3.1.3 | 網路規劃圖 | 5d | 2010-03-19 | 2010-03-25 | 85FF |  |  |  | 0d |  | 10,000 |
| 88 | 1.3.1.4 | 庭園造景設計 | 5d | 2010-03-19 | 2010-03-25 | 85FF |  |  |  | 0d |  | 5,000 |
| 89 | 1.3.1.5 | 保全系統藍圖 | 3d | 2010-03-23 | 2010-03-25 | 85FF |  |  |  | 0d |  | 5,000 |
| 90 | 1.3.1.6 | 內部裝璜設計 | 10d | 2010-03-12 | 2010-03-25 | 85FF |  |  |  | 0d |  | 5,000 |
| 91 | 1.3.2 | **施工準備** | 4d | 2010-03-26 | 2010-03-31 | 84, 30 |  |  |  | 0d |  | 95,000 |
| 92 | 1.3.2.1 | 建築執照 | 3d | 2010-03-26 | 2010-03-30 |  |  |  |  | 0d |  | 5,000 |
| 93 | 1.3.2.2 | 臨時水、電 | 1d | 2010-03-31 | 2010-03-31 | 92 |  |  |  | 0d |  | 30,000 |
| 94 | 1.3.2.3 | 工地辦公室 | 3d | 2010-03-26 | 2010-03-30 | 92SS |  |  |  | 1d |  | 60,000 |
| 95 | 1.3.3 | **土地整地** | 3d | 2010-04-01 | 2010-04-05 | 91 |  |  |  | 0d |  | 140,000 |
| 96 | 1.3.3.1 | 工地丈量 | 3d | 2010-04-01 | 2010-04-05 |  |  |  |  | 0d |  | 30,000 |
| 97 | 1.3.3.2 | 清除地上物 | 3d | 2010-04-01 | 2010-04-05 | 96SS |  |  |  | 0d |  | 50,000 |
| 98 | 1.3.3.3 | 工地圍籬 | 3d | 2010-04-01 | 2010-04-05 | 97SS |  |  |  | 0d |  | 60,000 |
| 99 | 1.3.4 | **地基構建** | 9d | 2010-04-06 | 2010-04-16 | 95, 35 |  |  |  | 0d |  | 250,000 |
| 100 | 1.3.4.1 | 地基開挖 | 3d | 2010-04-06 | 2010-04-08 |  |  |  |  | 0d |  | 100,000 |
| 101 | 1.3.4.2 | 餘土回填 | 3d | 2010-04-09 | 2010-04-13 | 100 |  |  |  | 0d |  | 50,000 |
| 102 | 1.3.4.3 | 地基灌漿 | 3d | 2010-04-14 | 2010-04-16 | 101 |  |  |  | 0d |  | 100,000 |

| ID | WBS | Task | Duration | Start | Finish | Predecessors | Total slack | Free slack | Cost |
| --- | --- | --- | --- | --- | --- | --- | --- | --- | --- |
| 103 | 1.3.5 | **主體結構** | 60d | 2010-04-19 | 2010-07-09 | 99 | 0d |  | 1,250,000 |
| 104 | 1.3.5.1 | 一樓施工 | 20d | 2010-04-19 | 2010-05-14 | 102 | 0d |  | 300,000 |
| 105 | 1.3.5.2 | 二樓施工 | 20d | 2010-05-17 | 2010-06-11 | 104 | 0d |  | 300,000 |
| 106 | 1.3.5.3 | 頂樓施工 | 10d | 2010-06-14 | 2010-06-25 | 105 | 0d |  | 200,000 |
| 107 | 1.3.5.4 | 門窗工程 | 10d | 2010-06-28 | 2010-07-09 | 106 | 7d |  | 300,000 |
| 108 | 1.3.5.5 | 外牆施工 | 10d | 2010-06-28 | 2010-07-09 | 106 | 7d |  | 150,000 |
| 109 | 1.3.6 | **外管工程** | 10d | 2010-06-28 | 2010-07-09 | 106 | 27d |  | 53,000 |
| 110 | 1.3.6.1 | 電力工程 | 10d | 2010-06-28 | 2010-07-09 |  | 27d |  | 30,000 |
| 111 | 1.3.6.2 | 視訊工程 | 5d | 2010-06-28 | 2010-07-02 |  | 32d |  | 6,000 |
| 112 | 1.3.6.3 | 自來水工程 | 10d | 2010-06-28 | 2010-07-09 |  | 27d |  | 6,000 |
| 113 | 1.3.6.4 | 瓦斯工程 | 10d | 2010-06-28 | 2010-07-09 |  | 27d |  | 6,000 |
| 114 | 1.3.6.5 | 電信工程 | 5d | 2010-06-28 | 2010-07-02 |  | 32d |  | 5,000 |
| 115 | 1.3.7 | **內部水電工程** | 10d | 2010-06-28 | 2010-07-09 | 106 | 0d |  | 950,000 |
| 116 | 1.3.7.1 | 廚具工程 | 10d | 2010-06-28 | 2010-07-09 |  | 0d |  | 200,000 |
| 117 | 1.3.7.2 | 視訊工程 | 3d | 2010-06-28 | 2010-06-30 |  | 7d |  | 200,000 |
| 118 | 1.3.7.3 | 電力工程 | 7d | 2010-06-28 | 2010-07-06 |  | 3d |  | 50,000 |
| 119 | 1.3.7.4 | 保全工程 | 7d | 2010-06-28 | 2010-07-06 | 47 | 3d | 0d | 70,000 |
| 120 | 1.3.7.5 | 網路工程 | 3d | 2010-06-28 | 2010-06-30 |  | 7d |  | 30,000 |
| 121 | 1.3.7.6 | 衛浴工程 | 7d | 2010-06-28 | 2010-07-06 |  | 3d |  | 100,000 |
| 122 | 1.3.7.7 | 空調工程 | 7d | 2010-06-28 | 2010-07-06 |  | 3d |  | 300,000 |
| 123 | 1.3.8 | **取得使用執照** | 15d | 2010-07-12 | 2010-07-30 | 115 | 12d |  | 11,000 |
| 124 | 1.3.8.1 | 取得建物使用執照 | 5d | 2010-07-12 | 2010-07-16 |  | 12d | 0d | 3,000 |
| 125 | 1.3.8.2 | 取得建物所有權狀 | 5d | 2010-07-19 | 2010-07-23 | 124 | 12d | 0d | 3,000 |
| 126 | 1.3.8.3 | 取得民宿經營執照 | 5d | 2010-07-26 | 2010-07-30 | 125 | 12d |  | 5,000 |

| ID | WBS | Task | Duration | Start | Finish | Predecessors | Total slack | Free slack | Cost |
| --- | --- | --- | --- | --- | --- | --- | --- | --- | --- |
| 127 | 1.3.9 | **內部裝修工程** | 20d | 2010-07-12 | 2010-08-06 | 115, 39 | 0d |  | 660,000 |
| 128 | 1.3.9.1 | 內部裝璜 | 20d | 2010-07-12 | 2010-08-06 |  | 0d |  | 600,000 |
| 129 | 1.3.9.2 | 油漆 | 5d | 2010-08-02 | 2010-08-06 | 128FF | 0d |  | 60,000 |
| 130 | 1.3.10 | **景觀設計** | 10d | 2010-07-12 | 2010-07-23 | 103, 43 | 7d | 0d | 600,000 |
| 131 | 1.3.10.1 | 屋前庭院造景 | 10d | 2010-07-12 | 2010-07-23 |  | 7d | 0d | 200,000 |
| 132 | 1.3.10.2 | 露天用餐區 | 5d | 2010-07-12 | 2010-07-16 |  | 21d |  | 100,000 |
| 133 | 1.3.10.3 | 停車場 | 5d | 2010-07-12 | 2010-07-16 |  | 21d |  | 300,000 |
| 134 | 1.3.11 | **購置內部傢俱** | 5d | 2010-08-09 | 2010-08-13 | 127 | 2d | 0d | 620,000 |
| 135 | 1.3.11.1 | 家電設備 | 5d | 2010-08-09 | 2010-08-13 |  | 2d | 0d | 300,000 |
| 136 | 1.3.11.2 | 廚房用具 | 5d | 2010-08-09 | 2010-08-13 | 135SS | 2d | 0d | 100,000 |
| 137 | 1.3.11.3 | 餐具 | 5d | 2010-08-09 | 2010-08-13 | 136SS | 2d | 0d | 20,000 |
| 138 | 1.3.11.4 | 桌椅 | 5d | 2010-08-09 | 2010-08-13 | 137SS | 2d |  | 200,000 |
| 139 | 1.4 | **民宿資訊平台建立計畫** | 111d | 2010-03-11 | 2010-08-12 | 23 | 3d | 0d | 121,000 |
| 140 | 1.4.1 | 資訊平台維護及管理計畫 | 3d | 2010-03-11 | 2010-03-15 |  | 111d |  |  |
| 141 | 1.4.2 | **自建/外包評估** | 4d | 2010-03-11 | 2010-03-16 |  | 108d |  |  |
| 142 | 1.4.2.1 | **開立規格與需求** | 1d | 2010-03-11 | 2010-03-11 |  | 108d |  |  |
| 143 | 1.4.2.1.1 | 硬體規格 | 1d | 2010-03-11 | 2010-03-11 |  | 109d | 0d |  |
| 144 | 1.4.2.1.2 | 軟體規格 | 1d | 2010-03-11 | 2010-03-11 |  | 109d | 0d |  |
| 145 | 1.4.2.1.3 | 資訊平台內容需求 | 1d | 2010-03-11 | 2010-03-11 |  | 108d | 0d |  |
| 146 | 1.4.2.2 | 廠商詢價 | 3d | 2010-03-12 | 2010-03-16 | 143, 144, 145 | 109d | 0d |  |
| 147 | 1.4.2.3 | 選擇自建或外包 | 1d | 2010-03-16 | 2010-03-16 | 146FF | 109d | 0d |  |
| 148 | 1.4.3 | **軟硬體建設** | 4d | 2010-08-09 | 2010-08-12 | 134SS | 2d |  | 120,000 |
| 149 | 1.4.3.1 | 電腦硬體安裝 | 1d | 2010-08-09 | 2010-08-09 |  | 4d | 0d | 40,000 |
| 150 | 1.4.3.2 | 電腦軟體安裝 | 1d | 2010-08-09 | 2010-08-09 | 149FF | 4d | 0d | 40,000 |
| 151 | 1.4.3.3 | 網路系統安裝 | 1d | 2010-08-09 | 2010-08-09 | 149FF | 4d | 0d | 10,000 |
| 152 | 1.4.3.4 | 資訊平台軟體內容設計 | 3d | 2010-08-09 | 2010-08-11 | 145, 149FF | 2d | 0d | 30,000 |
| 153 | 1.4.3.5 | 資訊平台軟體安裝 | 1d | 2010-08-12 | 2010-08-12 | 149, 150, 151, 152 | 2d | 0d |  |

| ID | WBS | Task | Duration | Start | Finish | Predecessors | Baseline start | Baseline finish | Baseline duration | Total slack | Free slack | Work | Cost | Baseline cost |
| --- | --- | --- | --- | --- | --- | --- | --- | --- | --- | --- | --- | --- | --- | --- |
| 154 | 1.4.4 | **使用者測試及驗收** | 4d | 2010-08-09 | 2010-08-12 |  |  |  |  | 2d | 0d |  |  |  |
| 155 | 1.4.4.1 | 電腦硬體測試 | 1d | 2010-08-09 | 2010-08-09 | 149FF |  |  |  | 5d | 3d |  |  |  |
| 156 | 1.4.4.2 | 電腦軟體測試 | 1d | 2010-08-09 | 2010-08-09 | 150FF |  |  |  | 5d | 3d |  |  |  |
| 157 | 1.4.4.3 | 網路系統測試 | 1d | 2010-08-09 | 2010-08-09 | 151FF |  |  |  | 5d | 3d |  |  |  |
| 158 | 1.4.4.4 | 資訊平台測試 | 1d | 2010-08-12 | 2010-08-12 | 153FF |  |  |  | 2d | 0d |  |  |  |
| 159 | 1.4.5 | 設備維護及資料更新 | 1d | 2010-08-12 | 2010-08-12 | 154FF |  |  |  | 3d |  |  | 1,000 |  |
| 160 | 1.5 | **人力需求規劃** | 66d | 2010-03-11 | 2010-06-10 | 23 | 2004-09-01 | 2005-05-13 | 183d | 48d | 0d | 30h | 210,000 | 210,000 |
| 161 | 1.5.1 | **人力資源管理** | 5d | 2010-03-11 | 2010-03-17 |  | 2004-09-01 | 2004-09-08 | 6d | 48d | 0d |  | 50,000 | 50,000 |
| 162 | 1.5.1.1 | **人員計劃** | 5d | 2010-03-11 | 2010-03-17 |  | 2004-09-01 | 2004-09-07 | 5d | 48d |  |  |  |  |
| 163 | 1.5.1.1.1 | 教育訓練內容制定 | 5d | 2010-03-11 | 2010-03-17 |  | 2004-09-01 | 2004-09-07 | 5d | 48d |  |  |  |  |
| 164 | 1.5.1.1.2 | 各項服務內容制定 | 5d | 2010-03-11 | 2010-03-17 |  | 2004-09-01 | 2004-09-07 | 5d | 48d |  |  |  |  |
| 165 | 1.5.1.1.3 | 標準程序制定 | 5d | 2010-03-11 | 2010-03-17 |  | 2004-09-01 | 2004-09-07 | 5d | 48d |  |  |  |  |
| 166 | 1.5.2 | **人員招募** | 30d | 2010-03-18 | 2010-04-28 | 161 | 2004-09-10 | 2004-10-21 | 30d | 48d | 0d | 30h | 30,000 | 30,000 |
| 167 | 1.5.2.1 | 服務人員 | 30d | 2010-03-18 | 2010-04-28 |  | 2004-09-10 | 2004-10-21 | 30d | 48d |  | 10h |  |  |
| 168 | 1.5.2.2 | 廚房人員 | 30d | 2010-03-18 | 2010-04-28 |  | 2004-09-10 | 2004-10-21 | 30d | 48d |  | 10h |  |  |
| 169 | 1.5.2.3 | 清潔人員 | 30d | 2010-03-18 | 2010-04-28 |  | 2004-09-10 | 2004-10-21 | 30d | 48d |  | 10h |  |  |
| 170 | 1.5.2.4 | 解說人員 | 30d | 2010-03-18 | 2010-04-28 |  | 2004-09-10 | 2004-10-21 | 30d | 48d |  |  |  |  |
| 171 | 1.5.3 | **人員訓練計劃** | 20d | 2010-04-29 | 2010-05-26 | 166 | 2004-10-21 | 2004-11-17 | 20d | 48d | 0d |  | 130,000 | 130,000 |
| 172 | 1.5.3.1 | **Check in/out 訓練** | 10d | 2010-04-29 | 2010-05-12 |  | 2004-10-21 | 2004-11-03 | 10d | 58d |  |  | 50,000 | 50,000 |
| 173 | 1.5.3.1.1 | 禮儀 | 10d | 2010-04-29 | 2010-05-12 |  | 2004-10-21 | 2004-11-03 | 10d | 58d |  |  |  |  |
| 174 | 1.5.3.1.2 | 財務 | 10d | 2010-04-29 | 2010-05-12 |  | 2004-10-21 | 2004-11-03 | 10d | 58d |  |  |  |  |
| 175 | 1.5.3.1.3 | 外語 | 10d | 2010-04-29 | 2010-05-12 |  | 2004-10-21 | 2004-11-03 | 10d | 58d |  |  |  |  |
| 176 | 1.5.3.1.4 | 解說/旅客應對 | 10d | 2010-04-29 | 2010-05-12 |  | 2004-10-21 | 2004-11-03 | 10d | 58d |  |  |  |  |
| 177 | 1.5.3.2 | **客房清潔人員訓練** | 5d | 2010-04-29 | 2010-05-05 |  | 2004-10-21 | 2004-10-27 | 5d | 63d |  |  | 20,000 | 20,000 |
| 178 | 1.5.3.2.1 | 房間 | 5d | 2010-04-29 | 2010-05-05 |  | 2004-10-21 | 2004-10-27 | 5d | 63d |  |  |  |  |
| 179 | 1.5.3.2.2 | 擺設 | 5d | 2010-04-29 | 2010-05-05 |  | 2004-10-21 | 2004-10-27 | 5d | 63d |  |  |  |  |
| 180 | 1.5.3.2.3 | 餐廳 | 5d | 2010-04-29 | 2010-05-05 |  | 2004-10-21 | 2004-10-27 | 5d | 63d |  |  |  |  |
| 181 | 1.5.3.2.4 | 走廊 | 3d | 2010-04-29 | 2010-05-03 |  | 2004-10-21 | 2004-10-25 | 3d | 65d |  |  |  |  |

| ID | WBS | Task | Duration | Start | Finish | Predecessors | Baseline start | Baseline finish | Baseline duration | Total slack | Free slack | Cost | Baseline cost |
| --- | --- | --- | --- | --- | --- | --- | --- | --- | --- | --- | --- | --- | --- |
| 182 | 1.5.3.3 | **廚房人員訓練** | 20d | 2010-04-29 | 2010-05-26 |  | 2004-10-21 | 2004-11-17 | 20d | 48d |  | 20,000 | 20,000 |
| 183 | 1.5.3.3.1 | 菜單 | 7d | 2010-04-29 | 2010-05-07 |  | 2004-10-21 | 2004-10-29 | 7d | 61d |  |  |  |
| 184 | 1.5.3.3.2 | 烹調 | 20d | 2010-04-29 | 2010-05-26 |  | 2004-10-21 | 2004-11-17 | 20d | 48d |  |  |  |
| 185 | 1.5.3.3.3 | 碗盤 | 5d | 2010-04-29 | 2010-05-05 |  | 2004-10-21 | 2004-10-27 | 5d | 63d |  |  |  |
| 186 | 1.5.3.4 | **環境整理人員訓練** | 5d | 2010-04-29 | 2010-05-05 |  | 2004-10-21 | 2004-10-27 | 5d | 63d |  | 20,000 | 20,000 |
| 187 | 1.5.3.4.1 | 樹木/花草 | 5d | 2010-04-29 | 2010-05-05 |  | 2004-10-21 | 2004-10-27 | 5d | 63d |  |  |  |
| 188 | 1.5.3.4.2 | 環境水土保持 | 5d | 2010-04-29 | 2010-05-05 |  | 2004-10-21 | 2004-10-27 | 5d | 63d |  |  |  |
| 189 | 1.5.3.4.3 | 垃圾 | 3d | 2010-04-29 | 2010-05-03 |  | 2004-10-21 | 2004-10-25 | 3d | 65d |  |  |  |
| 190 | 1.5.3.5 | **管理人員訓練** | 1d | 2010-04-29 | 2010-04-29 |  | 2004-10-21 | 2004-10-21 | 1d | 67d |  | 20,000 | 20,000 |
| 191 | 1.5.3.5.1 | 衝突管理 | 1d | 2010-04-29 | 2010-04-29 |  | 2004-10-21 | 2004-10-21 | 1d | 67d |  |  |  |
| 192 | 1.5.3.5.2 | 客房安排技巧 | 1d | 2010-04-29 | 2010-04-29 |  | 2004-10-21 | 2004-10-21 | 1d | 67d |  |  |  |
| 193 | 1.5.4 | 人員訓練結果驗收 | 1d | 2010-05-27 | 2010-05-27 | 171 | 2004-11-22 | 2004-11-22 | 1d | 48d | 0d |  |  |
| 194 | 1.5.5 | 人員運作 | 10d | 2010-05-28 | 2010-06-10 | 193 | 2005-03-02 | 2005-03-15 | 10d | 48d |  |  |  |
| 195 | 1.6 | **服務客戶計劃** | 160d | 2010-01-01 | 2010-08-12 |  |  |  |  | 3d |  | 127,000 |  |
| 196 | 1.6.1 | **行銷計劃** | 89d | 2010-04-12 | 2010-08-12 |  |  |  |  | 3d | 0d | 114,000 |  |
| 197 | 1.6.1.1 | **活動設計** | 44d | 2010-06-14 | 2010-08-12 |  |  |  |  | 3d |  | 62,000 |  |
| 198 | 1.6.1.1.1 | 開業前宣傳計劃 | 23d | 2010-07-13 | 2010-08-12 | 203FF |  |  |  | 3d | 0d | 5,000 |  |
| 199 | 1.6.1.1.2 | 開業優惠活動規劃 | 15d | 2010-07-23 | 2010-08-12 | 198FF |  |  |  | 3d |  | 2,000 |  |
| 200 | 1.6.1.1.3 | 旅游景點介紹規劃 | 23d | 2010-07-13 | 2010-08-12 | 203FF |  |  |  | 3d |  | 2,000 |  |
| 201 | 1.6.1.1.4 | 淡季促銷規劃 | 27d | 2010-07-07 | 2010-08-12 | 203FF |  |  |  | 3d |  | 2,000 |  |
| 202 | 1.6.1.1.5 | 解說流程規劃 | 10d | 2010-07-30 | 2010-08-12 | 203FF |  |  |  | 3d |  | 1,000 |  |
| 203 | 1.6.1.1.6 | 特色網站建立 | 44d | 2010-06-14 | 2010-08-12 | 139FF |  |  |  | 3d | 0d | 50,000 |  |
| 204 | 1.6.1.2 | **服務設施規劃** | 66d | 2010-04-12 | 2010-07-13 |  |  |  |  | 26d |  | 52,000 |  |
| 205 | 1.6.1.2.1 | 服務風格 | 66d | 2010-04-12 | 2010-07-13 | 198SF |  |  |  | 26d |  | 2,000 |  |
| 206 | 1.6.1.2.2 | 軟硬體建購 | 66d | 2010-04-12 | 2010-07-13 | 198SF |  |  |  | 26d |  | 50,000 |  |

| ID | WBS | Task | Duration | Start | Finish | Predecessors | Baseline start | Baseline finish | Baseline duration | Total slack | Free slack | Cost | Baseline cost |
| --- | --- | --- | --- | --- | --- | --- | --- | --- | --- | --- | --- | --- | --- |
| 207 | 1.6.2 | **客戶滿意度計劃** | 137d | 2010-01-01 | 2010-07-13 |  |  |  |  | 26d |  | 13,000 |  |
| 208 | 1.6.2.1 | **滿意度調查** | 66d | 2010-01-01 | 2010-04-02 |  |  |  |  | 97d |  | 13,000 |  |
| 209 | 1.6.2.1.1 | 問卷方式 | 66d | 2010-01-01 | 2010-04-02 |  |  |  |  | 97d |  | 10,000 |  |
| 210 | 1.6.2.1.2 | 口頭方式 | 66d | 2010-01-01 | 2010-04-02 |  |  |  |  | 97d |  | 3,000 |  |
| 211 | 1.6.2.2 | **建議處理** | 23d | 2010-06-10 | 2010-07-13 |  |  |  |  | 26d |  |  |  |
| 212 | 1.6.2.2.1 | 處理工作小組 | 23d | 2010-06-10 | 2010-07-13 | 198SF |  |  |  | 26d |  |  |  |
| 213 | 1.6.2.2.2 | 建議處理流程 | 23d | 2010-06-10 | 2010-07-13 | 198SF |  |  |  | 26d |  |  |  |
| 214 | 1.6.2.3 | **抱怨處理** | 23d | 2010-06-10 | 2010-07-13 |  |  |  |  | 26d |  |  |  |
| 215 | 1.6.2.3.1 | 處理工作小組 | 23d | 2010-06-10 | 2010-07-13 | 198SF |  |  |  | 26d |  |  |  |
| 216 | 1.6.2.3.2 | 抱怨處理流程 | 23d | 2010-06-10 | 2010-07-13 | 198SF |  |  |  | 26d |  |  |  |
| 217 | 1 | **生活管理** | 107d | 2010-03-11 | 2010-08-06 | 160SS | 2004-09-01 | 2004-10-18 | 34d | 7d |  | 95,000 | 55,000 |
| 218 | 1.1 | **住房維護與清潔** | 20d | 2010-03-11 | 2010-04-07 |  | 2004-09-01 | 2004-10-01 | 23d | 94d |  | 64,000 | 24,000 |
| 219 | 1.1.1 | 自行維護或外包評估 | 10d | 2010-03-11 | 2010-03-24 |  | 2004-09-01 | 2004-10-01 | 23d | 104d |  | 10,000 | 10,000 |
| 220 | 1.1.4 | 清潔及盥洗用具及耗材準備 | 10d | 2010-03-11 | 2010-03-24 |  | 2004-09-01 | 2004-09-14 | 10d | 104d |  | 10,000 | 10,000 |
| 221 | 1.7.1.3 | 床具寢具評估及準備 | 20d | 2010-03-11 | 2010-04-07 |  |  |  |  | 94d |  | 40,000 |  |
| 222 | 1.7.1.4 | 用具與耗材安全庫存管理 | 5d | 2010-03-11 | 2010-03-17 |  |  |  |  | 109d |  |  |  |
| 223 | 1.1.2 | 客房清潔與整理作業手冊 | 4d | 2010-03-11 | 2010-03-16 |  | 2004-09-01 | 2004-09-06 | 4d | 110d |  | 1,000 | 1,000 |
| 224 | 1.1.3 | 旅客住房須知 | 4d | 2010-03-11 | 2010-03-16 |  | 2004-09-01 | 2004-09-06 | 4d | 110d |  | 3,000 | 3,000 |
| 225 | 1.2 | **飲食規劃與管理** | 15d | 2010-03-11 | 2010-03-31 |  | 2004-09-01 | 2004-10-18 | 34d | 99d |  | 16,000 | 16,000 |
| 226 | 1.2.1 | 餐飲規劃 | 10d | 2010-03-11 | 2010-03-24 |  | 2004-09-01 | 2004-10-01 | 23d | 99d | 0d | 5,000 | 5,000 |
| 227 | 1.2.2 | 烹飪作業規範 | 5d | 2010-03-25 | 2010-03-31 | 226 | 2004-09-01 | 2004-09-15 | 11d | 99d |  | 1,000 | 1,000 |
| 228 | 1.2.3 | 飲食品質與衛生確保 | 5d | 2010-03-25 | 2010-03-31 | 226 | 2004-09-01 | 2004-10-18 | 34d | 99d |  | 10,000 | 10,000 |
| 229 | 1.3 | **環境維護** | 10d | 2010-07-26 | 2010-08-06 |  | 2004-09-01 | 2004-10-01 | 23d | 7d |  | 11,000 | 11,000 |
| 230 | 1.3.1 | 景觀說明與標示 | 10d | 2010-07-26 | 2010-08-06 | 131 | 2004-09-01 | 2004-10-01 | 23d | 7d | 0d | 10,000 | 10,000 |
| 231 | 1.3.2 | 環境維護工作手冊 | 10d | 2010-07-26 | 2010-08-06 | 230FF | 2004-09-01 | 2004-09-15 | 11d | 7d |  | 1,000 | 1,000 |

| ID | WBS | Task | Duration | Start | Finish | Baseline start | Baseline finish | Baseline duration | Total slack | Cost | Baseline cost |
| --- | --- | --- | --- | --- | --- | --- | --- | --- | --- | --- | --- |
| 232 | 1.4.3 | **員工生活管理** | 10d | 2010-03-11 | 2010-03-24 | 2004-09-01 | 2004-09-29 | 21d | 104d | 4,000 | 4,000 |
| 233 | 1.7.4.1 | 旅客應對與衝突管理教戰手冊 | 5d | 2010-03-11 | 2010-03-17 |  |  |  | 109d |  |  |
| 234 | 1.7.4.2 | 客房安排基本原則 | 5d | 2010-03-11 | 2010-03-17 |  |  |  | 109d |  |  |
| 235 | 1.4.3.1 | 員工獎懲辦法 | 10d | 2010-03-11 | 2010-03-24 | 2004-09-01 | 2004-09-29 | 21d | 104d | 1,000 | 1,000 |
| 236 | 1.4.3.2 | 員工工作日誌 | 5d | 2010-03-11 | 2010-03-17 | 2004-09-01 | 2004-09-09 | 7d | 109d | 3,000 | 3,000 |
