# WBSchart1-1

Schedule from MS Project, 2009-09-18 to 2010-07-06.

## Calendars

- 標準: Mon-Fri 08:00-12:00, 13:00-17:00; Sat-Sun off.

## Schedule

| ID | WBS | Task | Duration | Start | Finish | Predecessors | Total slack |
| --- | --- | --- | --- | --- | --- | --- | --- |
| 1 | 1 | **生產設備機自動化專案** | 208d? | 2009-09-18 | 2010-07-06 |  | 0d |
| 2 | 1.1 | **提案評估** | 62d? | 2009-09-18 | 2009-12-14 |  | 0d |
| 3 | 1.1.1 | 初步構想 | 20d | 2009-09-18 | 2009-10-15 |  | 0d |
| 4 | 1.1.2 | 製作系統雛形 | 20d | 2009-10-16 | 2009-11-12 | 3 | 0d |
| 5 | 1.1.3 | 檢討及構想修正 | 20d | 2009-11-13 | 2009-12-10 | 4 | 0d |
| 6 | 1.1.4 | 專案需求範疇 | 1d? | 2009-12-11 | 2009-12-11 | 5 | 0d |
| 7 | 1.1.5 | 評估報告及檢討 | 1d? | 2009-12-14 | 2009-12-14 | 6 | 0d |
| 8 | 1.2 | **工作計畫** | 15d | 2009-12-15 | 2010-01-04 |  | 0d |
| 9 | 1.2.1 | 活動及產出項目定義 | 2d | 2009-12-15 | 2009-12-16 | 7 | 0d |
| 10 | 1.2.2 | 人員及設備規劃 | 2d | 2009-12-17 | 2009-12-18 | 9 | 0d |
| 11 | 1.2.3 | 工作控管及報告規畫 | 2d | 2009-12-21 | 2009-12-22 | 10 | 0d |
| 12 | 1.2.4 | 預算規劃 | 3d | 2009-12-23 | 2009-12-25 | 11 | 0d |
| 13 | 1.2.5 | 時程規畫 | 1d | 2009-12-28 | 2009-12-28 | 12 | 0d |
| 14 | 1.2.6 | 專案計畫書撰寫及審核 | 5d | 2009-12-29 | 2010-01-04 | 13 | 0d |
| 15 | 1.3 | **技術研發** | 90d | 2010-01-05 | 2010-05-10 |  | 0d |
| 16 | 1.3.1 | **進行系統開發** | 28d | 2010-01-05 | 2010-02-11 |  | 0d |
| 17 | 1.3.1.1 | 製作步進馬達模組 | 7d | 2010-01-05 | 2010-01-13 | 14 | 0d |
| 18 | 1.3.1.2 | 完成驗收 | 7d | 2010-01-14 | 2010-01-22 | 17 | 0d |
| 19 | 1.3.1.3 | 執行PLC程式撰寫 | 7d | 2010-01-25 | 2010-02-02 | 18 | 0d |
| 20 | 1.3.1.4 | 完成驗收 | 7d | 2010-02-03 | 2010-02-11 | 19 | 0d |
| 21 | 1.3.2 | **進行整合測試** | 14d | 2010-02-12 | 2010-03-03 |  | 0d |
| 22 | 1.3.2.1 | 執行整合測試工作 | 7d | 2010-02-12 | 2010-02-22 | 20 | 0d |
| 23 | 1.3.2.2 | 完成驗收 | 7d | 2010-02-23 | 2010-03-03 | 22 | 0d |
| 24 | 1.3.3 | **進行使用者測試** | 48d | 2010-03-04 | 2010-05-10 |  | 0d |
| 25 | 1.3.3.1 | 規劃使用者測試方法與準則 | 12d | 2010-03-04 | 2010-03-19 | 23 | 0d |
| 26 | 1.3.3.2 | 撰寫SOP | 12d | 2010-03-22 | 2010-04-06 | 25 | 0d |
| 27 | 1.3.3.3 | 進行使用者測試驗收 | 12d | 2010-04-07 | 2010-04-22 | 26 | 0d |
| 28 | 1.3.3.4 | 完成驗收 | 12d | 2010-04-23 | 2010-05-10 | 27 | 0d |

| ID | WBS | Task | Duration | Start | Finish | Predecessors | Total slack |
| --- | --- | --- | --- | --- | --- | --- | --- |
| 29 | 1.4 | **上線教育** | 25d | 2010-05-11 | 2010-06-14 |  | 0d |
| 30 | 1.4.1 | 上線環境建置 | 3d | 2010-05-11 | 2010-05-13 | 28 | 0d |
| 31 | 1.4.2 | 檢核上線環境是否齊備 | 3d | 2010-05-14 | 2010-05-18 | 30 | 0d |
| 32 | 1.4.3 | 完成驗收 | 3d | 2010-05-19 | 2010-05-21 | 31 | 0d |
| 33 | 1.4.4 | **安排教育訓練** | 16d | 2010-05-24 | 2010-06-14 |  | 0d |
| 34 | 1.4.4.1 | 製做教育訓練教材 | 4d | 2010-05-24 | 2010-05-27 | 32 | 0d |
| 35 | 1.4.4.2 | 安排教育訓練 | 4d | 2010-05-28 | 2010-06-02 | 34 | 0d |
| 36 | 1.4.4.3 | 進行教育訓練 | 4d | 2010-06-03 | 2010-06-08 | 35 | 0d |
| 37 | 1.4.4.4 | 完成驗收 | 4d | 2010-06-09 | 2010-06-14 | 36 | 0d |
| 38 | 1.5 | **結案** | 16d | 2010-06-15 | 2010-07-06 |  | 0d |
| 39 | 1.5.1 | 製作結案報告 | 8d | 2010-06-15 | 2010-06-24 | 37 | 0d |
| 40 | 1.5.2 | 審核結案報告書 | 8d | 2010-06-25 | 2010-07-06 | 39 | 0d |
