# 行銷資訊系統開發

Schedule from MS Project, 2010-01-18 to 2010-12-29.
Sand County

## Calendars

- 標準: Mon-Fri 08:00-12:00, 13:00-17:00; Sat-Sun off.

## Schedule

| ID | WBS | Task | Type | Duration | Start | Finish | Predecessors | Total slack | Free slack | Constraint | Deadline |
| --- | --- | --- | --- | --- | --- | --- | --- | --- | --- | --- | --- |
| 1 | 1 | **行銷資訊系統開發** |  | 248d | 2010-01-18 | 2010-12-29 |  | -1305d | 0d |  |  |
| 2 | 1.1 | **專案規劃** |  | 30d | 2010-01-18 | 2010-02-26 |  | -1305d | 0d |  | 2005-03-31 |
| 3 | 1.1.1 | **需求調查** |  | 13d | 2010-01-18 | 2010-02-03 |  | -1305d | 0d |  |  |
| 4 | 1.1.1.1 | 經銷商需求調查 |  | 8d | 2010-01-18 | 2010-01-27 |  | -1305d | 0d | start no earlier than 2010-01-17 |  |
| 5 | 1.1.1.2 | 自營商需求調查 |  | 8d | 2010-01-18 | 2010-01-27 |  | -1305d | 0d | start no earlier than 2010-01-17 |  |
| 6 | 1.1.1.3 | 供應商需求調查 |  | 8d | 2010-01-18 | 2010-01-27 |  | -1305d | 0d | start no earlier than 2010-01-17 |  |
| 7 | 1.1.1.4 | 內部作業需求調查 |  | 5d | 2010-01-28 | 2010-02-03 | 4, 5, 6 | -1305d | 0d | start no earlier than 2010-01-17 |  |
| 8 | 1.1.2 | **專案評估及工作指派** |  | 5d | 2010-02-04 | 2010-02-10 | 3 | -1305d | 0d |  |  |
| 9 | 1.1.2.1 | 可行性分析 |  | 4d | 2010-02-04 | 2010-02-09 | 3 | -1305d | 0d | start no earlier than 2010-01-17 |  |
| 10 | 1.1.2.2 | 專案認可 | milestone | 0d | 2010-02-09 | 2010-02-09 | 9 | -1304d | 0d | start no earlier than 2010-01-17 |  |
| 11 | 1.1.2.3 | 專案主持人指派 |  | 1d | 2010-02-10 | 2010-02-10 | 9 | -1305d | 0d | start no earlier than 2010-01-17 |  |
| 12 | 1.1.2.4 | 專案團隊組成 |  | 1d | 2010-02-10 | 2010-02-10 | 9 | -1305d | 0d | start no earlier than 2010-01-17 |  |
| 13 | 1.1.3 | **專案架構規劃** |  | 12d | 2010-02-11 | 2010-02-26 | 8 | -1281d | 0d |  |  |
| 14 | 1.1.3.1 | 資料呈現方式規劃 |  | 5d | 2010-02-11 | 2010-02-17 | 8 | -1274d | 0d | start no earlier than 2010-01-17 |  |
| 15 | 1.1.3.2 | 系統整合方式規劃 |  | 12d | 2010-02-11 | 2010-02-26 | 8 | -1281d | 0d | start no earlier than 2010-01-17 |  |
| 16 | 1.2 | **相關事項確認** |  | 25d | 2010-02-11 | 2010-03-17 | 8 | -1305d | 0d |  |  |
| 17 | 1.2.1 | **系統規格確認** |  | 25d | 2010-02-11 | 2010-03-17 | 8 | -1305d | 0d |  | 2005-03-16 |
| 18 | 1.2.1.1 | 內部確認 |  | 5d | 2010-02-11 | 2010-02-17 | 8 | -1303d | 0d | start no earlier than 2010-01-17 |  |
| 19 | 1.2.1.2 | **資料提交** |  | 10d | 2010-02-11 | 2010-02-24 | 8 | -1305d | 0d |  |  |
| 20 | 1.2.1.2.1 | 整理各系統所需資料 |  | 7d | 2010-02-11 | 2010-02-19 | 8 | -1305d | 0d | start no earlier than 2010-01-17 |  |
| 21 | 1.2.1.2.2 | 提交廠商 |  | 3d | 2010-02-22 | 2010-02-24 | 18, 20 | -1305d | 0d | start no earlier than 2010-01-17 |  |
| 22 | 1.2.1.3 | 廠商確認規格 |  | 15d | 2010-02-25 | 2010-03-17 | 21 | -1305d | 0d | start no earlier than 2010-01-17 |  |
| 23 | 1.2.1.4 | 規格確定 | milestone | 0d | 2010-03-17 | 2010-03-17 | 24, 22 | -1305d | 0d | start no earlier than 2010-01-17 |  |
| 24 | 1.2.2 | **合作廠商評選** |  | 10d | 2010-02-11 | 2010-02-24 | 8 | -1290d | 0d |  |  |
| 25 | 1.2.2.1 | 廠商清單 |  | 2d | 2010-02-11 | 2010-02-12 | 8 | -1290d | 0d | start no earlier than 2010-01-17 |  |
| 26 | 1.2.2.2 | 廠商評估 |  | 8d | 2010-02-15 | 2010-02-24 | 25 | -1290d | 0d | start no earlier than 2010-01-17 |  |
| 27 | 1.2.2.3 | 合作廠商確認 | milestone | 0d | 2010-02-24 | 2010-02-24 | 26 | -1290d | 0d | start no earlier than 2010-01-17 |  |

| ID | WBS | Task | Type | Duration | Start | Finish | Predecessors | Total slack | Constraint |
| --- | --- | --- | --- | --- | --- | --- | --- | --- | --- |
| 28 | 1.3 | **執行** |  | 80d | 2010-03-18 | 2010-07-07 | 16 | 0d |  |
| 29 | 1.3.1 | **系統開發** |  | 50d | 2010-03-18 | 2010-05-26 | 16 | 0d |  |
| 30 | 1.3.1.1 | 開發【經銷通路服務】系統 |  | 50d | 2010-03-18 | 2010-05-26 | 16 | 0d | start no earlier than 2010-01-17 |
| 31 | 1.3.1.2 | 開發【供應商服務】系統 |  | 50d | 2010-03-18 | 2010-05-26 | 16 | 0d | start no earlier than 2010-01-17 |
| 32 | 1.3.2 | 檔案傳輸測試1st run |  | 20d | 2010-05-27 | 2010-06-23 | 29 | 0d | start no earlier than 2010-01-17 |
| 33 | 1.3.3 | 系統修改及整合 |  | 5d | 2010-06-24 | 2010-06-30 | 32 | 0d | start no earlier than 2010-01-17 |
| 34 | 1.3.4 | 檔案傳輸測試2nd run |  | 5d | 2010-07-01 | 2010-07-07 | 33 | 0d | start no earlier than 2010-01-17 |
| 35 | 1.3.5 | 系統開發完成 | milestone | 0d | 2010-07-07 | 2010-07-07 | 34 | 0d | start no earlier than 2010-01-17 |
| 36 | 1.4 | **先導計劃與教育訓練** |  | 40d | 2010-07-08 | 2010-09-01 | 35 | 0d |  |
| 37 | 1.4.1 | **內部先導計畫** |  | 6d | 2010-07-08 | 2010-07-15 | 34 | 0d |  |
| 38 | 1.4.1.1 | 提出受訓人員名單 |  | 1d | 2010-07-08 | 2010-07-08 | 34 | 0d | start no earlier than 2010-01-17 |
| 39 | 1.4.1.2 | 內部教育訓練 |  | 5d | 2010-07-09 | 2010-07-15 | 38 | 0d | start no earlier than 2010-01-17 |
| 40 | 1.4.2 | **外部先導計畫** |  | 12d | 2010-07-16 | 2010-08-02 | 37 | 0d |  |
| 41 | 1.4.2.1 | 提出先導廠商名單 |  | 2d | 2010-07-16 | 2010-07-19 | 37 | 0d | start no earlier than 2010-01-17 |
| 42 | 1.4.2.2 | 舉辦先導說明會 |  | 10d | 2010-07-20 | 2010-08-02 | 41 | 0d | start no earlier than 2010-01-17 |
| 43 | 1.4.3 | **先導測試及修正** |  | 22d | 2010-08-03 | 2010-09-01 | 40 | 0d |  |
| 44 | 1.4.3.1 | 5.3.1測試 |  | 8d | 2010-08-03 | 2010-08-12 | 40 | 0d | start no earlier than 2010-01-17 |
| 45 | 1.4.3.2 | 檢討與修正 |  | 14d | 2010-08-13 | 2010-09-01 | 44 | 0d | start no earlier than 2010-01-17 |
| 46 | 1.4.3.3 | 先導測試及修正結果整合 | milestone | 0d | 2010-09-01 | 2010-09-01 | 45 | 0d | start no earlier than 2010-01-17 |
| 47 | 1.5 | **.系統上線** |  | 15d | 2010-09-02 | 2010-09-22 | 46 | 0d |  |
| 48 | 1.5.1 | **舉辦上線說明會** |  | 10d | 2010-09-02 | 2010-09-15 | 45 | 0d |  |
| 49 | 1.5.1.1 | 廠商邀約 |  | 9d | 2010-09-02 | 2010-09-14 | 45 | 0d | start no earlier than 2010-01-17 |
| 50 | 1.5.1.2 | 會前準備 |  | 9d | 2010-09-02 | 2010-09-14 | 45 | 0d | start no earlier than 2010-01-17 |
| 51 | 1.5.1.3 | 說明會 |  | 1d | 2010-09-15 | 2010-09-15 | 50, 49 | 0d | start no earlier than 2010-01-17 |
| 52 | 1.5.2 | 接受申請 |  | 5d | 2010-09-16 | 2010-09-22 | 51 | 0d | start no earlier than 2010-01-17 |
| 53 | 1.5.3 | 廠商申請 | milestone | 0d | 2010-09-22 | 2010-09-22 | 52 | 0d | start no earlier than 2010-01-17 |
| 54 | 1.5.4 | 正式上線 | milestone | 0d | 2010-09-22 | 2010-09-22 | 53 | 0d | start no earlier than 2010-01-17 |

| ID | WBS | Task | Type | Duration | Start | Finish | Predecessors | Total slack | Constraint |
| --- | --- | --- | --- | --- | --- | --- | --- | --- | --- |
| 55 | 1.6 | **e化效益執行情況說明** |  | 35d | 2010-11-04 | 2010-12-22 | 67 | 0d |  |
| 56 | 1.6.1 | **問題與修正** |  | 35d | 2010-11-04 | 2010-12-22 | 67 | 0d |  |
| 57 | 1.6.1.1 | 問題提出 |  | 15d | 2010-11-04 | 2010-11-24 | 67 | 0d | start no earlier than 2010-01-17 |
| 58 | 1.6.1.2 | 檢討會議及工作指派 |  | 1d | 2010-11-25 | 2010-11-25 | 57 | 0d | start no earlier than 2010-01-17 |
| 59 | 1.6.1.3 | 問題修正 |  | 15d | 2010-11-26 | 2010-12-16 | 58 | 0d | start no earlier than 2010-01-17 |
| 60 | 1.6.1.4 | 問題追蹤 |  | 4d | 2010-12-17 | 2010-12-22 | 59 | 0d | start no earlier than 2010-01-17 |
| 61 | 1.6.2 | 使用情況分析 |  | 25d | 2010-11-04 | 2010-12-08 | 67 | 15d | start no earlier than 2010-01-17 |
| 62 | 1.6.3 | 使用者滿意度調查 |  | 25d | 2010-11-04 | 2010-12-08 | 67 | 15d | start no earlier than 2010-01-17 |
| 63 | 1.7 | **結案報告** |  | 5d | 2010-12-23 | 2010-12-29 | 56 | 0d |  |
| 64 | 1.7.1 | 專案結果蒐集 |  | 4d | 2010-12-23 | 2010-12-28 | 56 | 0d | start no earlier than 2010-01-17 |
| 65 | 1.7.2 | 書面報告 |  | 1d | 2010-12-29 | 2010-12-29 | 64 | 0d | start no earlier than 2010-01-17 |
| 66 | 1.8 | 結案 | milestone | 0d | 2010-12-29 | 2010-12-29 | 65 | 0d | start no earlier than 2010-01-17 |
| 67 | 1.9 | 使用及維護 |  | 30d | 2010-09-23 | 2010-11-03 | 54 | 0d | start no earlier than 2010-01-17 |
