# PMS WBS

Schedule from MS Project, 2008-02-14 to 2012-01-19, A marks actual dates.

## Calendars

- 標準: Mon-Fri 08:00-12:00, 13:00-17:00; Sat-Sun off.

## Schedule

| ID | WBS | Task | Type | Duration | Start | Finish | Predecessors | Complete | Remaining | Baseline start | Baseline finish | Baseline duration | Total slack | Free slack | Constraint | Text2 | Text1 |
| --- | --- | --- | --- | --- | --- | --- | --- | --- | --- | --- | --- | --- | --- | --- | --- | --- | --- |
| 1 | 1 | **軟體開發設計時程甘特圖** |  | 1025d | 2008-02-14 A | 2012-01-19 |  |  | 1025d | 2008-02-14 | 2012-01-19 | 1025d | 0d |  |  | 1025 dys |  |
| 2 | 1.1 | **起始階段** |  | 20d | 2008-02-14 A | 2008-03-13 |  |  | 20d | 2008-02-14 | 2008-03-13 | 20d | 1005d |  |  | 20 dys |  |
| 3 | 1.1.1 | 起始階段工作摘要會議 | milestone | 0d | 2008-02-14 A | 2008-02-14 A |  | 100% |  | 2008-02-14 | 2008-02-14 | 0d |  |  | must finish on 2008-02-14 | 0 dys | 專案會議紀錄表 |
| 4 | 1.1.2 | 確認產出及工作範疇目標 |  | 2w | 2008-02-15 A | 2008-02-28 | 3 |  | 2w | 2008-02-15 | 2008-02-28 | 2w | 1015d | 0d |  | 2 wks | 專案摘要計畫書 |
| 5 | 1.1.3 | 確認主要里程碑 |  | 2w | 2008-02-15 A | 2008-02-28 | 4SS |  | 2w | 2008-02-15 | 2008-02-28 | 2w | 1015d |  |  | 2 wks | 主要里程碑活動及時間表 |
| 6 | 1.1.4 | **工作小組團隊成立** |  | 10d | 2008-02-15 A | 2008-02-28 |  |  | 10d | 2008-02-15 | 2008-02-28 | 10d | 1015d |  |  | 10 dys |  |
| 7 | 1.1.4.1 | 工作小組角色責任定義 |  | 2w | 2008-02-15 A | 2008-02-28 | 4SS |  | 2w | 2008-02-15 | 2008-02-28 | 2w | 1015d |  |  | 2 wks | 專案職責表、專案聯絡表 |
| 8 | 1.1.4.2 | 工作小組成員工作分派 |  | 2w | 2008-02-15 A | 2008-02-28 | 4SS |  | 2w | 2008-02-15 | 2008-02-28 | 2w | 0d |  |  | 2 wks | 責任分派矩陣表 |
| 9 | 1.1.5 | 起始階段報告準備 |  | 1w | 2008-02-29 A | 2008-03-06 | 8 |  | 1w | 2008-02-29 | 2008-03-06 | 1w | 1010d | 0d |  | 1 wk | 簡報大綱 |
| 10 | 1.1.6 | 起始階段報告-向經營團隊(子專案4) | milestone | 0d | 2008-03-06 | 2008-03-06 | 9 |  |  | 2008-03-06 | 2008-03-06 | 0d | 1010d |  |  | 0 dys | 簡報檔、專案會議紀錄表 |
| 11 | 1.1.7 | Kick-off會議(子專案4) | milestone | 0d | 2008-03-13 A | 2008-03-13 A | 10 | 100% |  | 2008-03-13 | 2008-03-13 | 0d |  |  | must finish on 2008-03-13 | 0 dys | 專案會議紀錄表 |
| 12 | 1.2 | **計畫階段** |  | 295d | 2008-03-14 | 2009-04-30 |  |  |  | 2008-03-14 | 2009-04-30 | 295d | 0d |  |  | 295 dys |  |
| 13 | 1.2.1 | **系統需求分析** |  | 135d | 2008-03-14 | 2008-09-18 |  |  |  | 2008-03-14 | 2008-09-18 | 135d | 0d |  |  | 135 dys |  |
| 14 | 1.2.1.1 | **系統需求分析及構想發展** |  | 60d | 2008-03-14 | 2008-06-05 | 11 |  |  | 2008-03-14 | 2008-06-05 | 60d | 0d |  |  | 60 dys |  |
| 15 | 1.2.1.1.1 | 現有Web-Based PMS調查分析 |  | 12w | 2008-03-14 | 2008-06-05 |  |  |  | 2008-03-14 | 2008-06-05 | 12w | 0d |  |  | 12 wks | 分析報告 |
| 16 | 1.2.1.1.2 | 初步系統概念發展及評估 |  | 12w | 2008-03-14 | 2008-06-05 |  |  |  | 2008-03-14 | 2008-06-05 | 12w | 0d |  |  | 12 wks | 評估報告 |
| 17 | 1.2.1.1.3 | 開發、測試環境及設備需求分析 |  | 12w | 2008-03-14 | 2008-06-05 |  |  |  | 2008-03-14 | 2008-06-05 | 12w | 0d |  |  | 12 wks | 設備需求建議書 |
| 18 | 1.2.1.2 | 製作初步系統需求說明書 |  | 6w | 2008-06-06 | 2008-07-17 | 14 |  |  | 2008-06-06 | 2008-07-17 | 6w | 0d |  |  | 6 wks | 系統需求說明書大綱 |
| 19 | 1.2.1.3 | 發表初步分析結果及構想 | milestone | 0d | 2008-07-17 | 2008-07-17 | 18 |  |  | 2008-07-17 | 2008-07-17 | 0d | 0d |  |  | 0 dys | 專案會議紀錄表 |
| 20 | 1.2.1.4 | 撰寫細部系統需求分析說明書 |  | 6w | 2008-07-18 | 2008-08-28 | 19 |  |  | 2008-07-18 | 2008-08-28 | 6w | 0d |  |  | 6 wks | 系統需求說明書初稿 |
| 21 | 1.2.1.5 | 審核及修改 |  | 3w | 2008-08-29 | 2008-09-18 | 20 |  |  | 2008-08-29 | 2008-09-18 | 3w | 0d |  |  | 3 wks | 系統需求說明書 |
| 22 | 1.2.1.6 | 完成驗收 | milestone | 0d | 2008-09-18 | 2008-09-18 | 21 |  |  | 2008-09-18 | 2008-09-18 | 0d | 0d |  |  | 0 dys | 完工驗收單、完工報告 |
| 23 | 1.2.2 | **系統規格定義** |  | 130d | 2008-09-19 | 2009-03-19 | 22 |  |  | 2008-09-19 | 2009-03-19 | 130d | 0d |  |  | 130 dys |  |
| 24 | 1.2.2.1 | 撰寫開發、測試環境及設備規格書 |  | 4w | 2008-09-19 | 2008-10-16 |  |  |  | 2008-09-19 | 2008-10-16 | 4w | 0d |  |  | 4 wks | 系統規格書大綱 |
| 25 | 1.2.2.2 | 撰寫系統設計規格書 |  | 16w | 2008-10-17 | 2009-02-05 | 24 |  |  | 2008-10-17 | 2009-02-05 | 16w | 0d |  |  | 16 wks | 系統規格書初稿 |
| 26 | 1.2.2.3 | 審核及修改 |  | 6w | 2009-02-06 | 2009-03-19 | 25 |  |  | 2009-02-06 | 2009-03-19 | 6w | 0d |  |  | 6 wks | 系統規格書 |
| 27 | 1.2.2.4 | 完成驗收 | milestone | 0d | 2009-03-19 | 2009-03-19 | 26 |  |  | 2009-03-19 | 2009-03-19 | 0d | 0d |  |  | 0 dys | 完工驗收單、完工報告 |
| 28 | 1.2.3 | 發展細部工作計畫 |  | 6w | 2009-03-20 | 2009-04-30 | 27 |  |  | 2009-03-20 | 2009-04-30 | 6w | 0d |  |  | 6 wks | 工作小組計畫書初稿 |
| 29 | 1.2.4 | 審核細部工作計畫 | milestone | 0d | 2009-04-30 | 2009-04-30 | 28 |  |  | 2009-04-30 | 2009-04-30 | 0d | 0d |  |  | 0 dys | 工作小組計畫書 |

Notes:
- 11: 小組工作分派

| ID | WBS | Task | Type | Duration | Start | Finish | Predecessors | Baseline start | Baseline finish | Baseline duration | Total slack | Free slack | Text2 | Text1 |
| --- | --- | --- | --- | --- | --- | --- | --- | --- | --- | --- | --- | --- | --- | --- |
| 30 | 1.3 | **執行階段** |  | 690d | 2009-05-01 | 2011-12-22 |  | 2009-05-01 | 2011-12-22 | 690d | 0d |  | 690 dys |  |
| 31 | 1.3.1 | **系統建置** |  | 440d | 2009-05-01 | 2011-01-06 |  | 2009-05-01 | 2011-01-06 | 440d | 0d |  | 440 dys |  |
| 32 | 1.3.1.1 | 建置開發、測試環境及設備 |  | 8w | 2009-05-01 | 2009-06-25 | 29 | 2009-05-01 | 2009-06-25 | 8w | 0d |  | 8 wks | 建置開發、測試環境及設備完工表 |
| 33 | 1.3.1.2 | **系統設計及驗證** |  | 330d | 2009-06-26 | 2010-09-30 |  | 2009-06-26 | 2010-09-30 | 330d | 0d |  | 330 dys |  |
| 34 | 1.3.1.2.1 | 程式開發與修正 |  | 30w | 2009-06-26 | 2010-01-21 | 32 | 2009-06-26 | 2010-01-21 | 30w | 0d |  | 30 wks | 程式初稿 |
| 35 | 1.3.1.2.2 | 單元測試 |  | 30w | 2009-10-02 | 2010-04-29 | 34FS-16w | 2009-10-02 | 2010-04-29 | 30w | 0d |  | 30 wks | 單元測試報告 |
| 36 | 1.3.1.2.3 | 功能測試 |  | 30w | 2010-01-08 | 2010-08-05 | 35FS-16w | 2010-01-08 | 2010-08-05 | 30w | 0d |  | 30 wks | 功能測試報告 |
| 37 | 1.3.1.2.4 | 整合測試 |  | 8w | 2010-08-06 | 2010-09-30 | 36 | 2010-08-06 | 2010-09-30 | 8w | 0d |  | 8 wks | 整合測試報告 |
| 38 | 1.3.1.3 | **完成系統測試** |  | 70d | 2010-10-01 | 2011-01-06 |  | 2010-10-01 | 2011-01-06 | 70d | 0d |  | 70 dys |  |
| 39 | 1.3.1.3.1 | 使用者測試 |  | 8w | 2010-10-01 | 2010-11-25 | 37 | 2010-10-01 | 2010-11-25 | 8w | 0d |  | 8 wks | 使用者測試報告 |
| 40 | 1.3.1.3.2 | 審核及修改 |  | 6w | 2010-11-26 | 2011-01-06 | 39 | 2010-11-26 | 2011-01-06 | 6w | 0d |  | 6 wks | 更新後的程式 |
| 41 | 1.3.1.3.3 | 完成驗收 | milestone | 0w | 2011-01-06 | 2011-01-06 | 40 | 2011-01-06 | 2011-01-06 | 0w | 0d |  | 0 dys | 完工驗收單、完工報告 |
| 42 | 1.3.2 | **上線規劃及執行** |  | 260d | 2010-10-01 | 2011-09-29 |  | 2010-10-01 | 2011-09-29 | 260d | 70d |  | 260 dys |  |
| 43 | 1.3.2.1 | **上線測試及作業環境建置** |  | 60d | 2010-10-01 | 2010-12-23 |  | 2010-10-01 | 2010-12-23 | 60d | 150d |  | 60 dys |  |
| 44 | 1.3.2.1.1 | 確認上線測試及作業環境所需設備 |  | 8w | 2010-10-01 | 2010-11-25 | 37 | 2010-10-01 | 2010-11-25 | 8w | 150d | 0d | 8 wks | 上線測試及作業環境所需設備清單檢查表 |
| 45 | 1.3.2.1.2 | 建置上線測試及作業環境 |  | 4w | 2010-11-26 | 2010-12-23 | 44 | 2010-11-26 | 2010-12-23 | 4w | 150d | 0d | 4 wks | 建置上線測試及作業環境完工表 |
| 46 | 1.3.2.1.3 | 完成驗收 | milestone | 0d | 2010-12-23 | 2010-12-23 | 45 | 2010-12-23 | 2010-12-23 | 0d | 150d | 0d | 0 dys | 完工驗收單、完工報告 |
| 47 | 1.3.2.2 | **系統上線** |  | 130d | 2010-12-24 | 2011-06-23 |  | 2010-12-24 | 2011-06-23 | 130d | 150d |  | 130 dys |  |
| 48 | 1.3.2.2.1 | 建立上線作業程序 |  | 8w | 2010-12-24 | 2011-02-17 | 46 | 2010-12-24 | 2011-02-17 | 8w | 150d | 0d | 8 wks | 上線作業SOP |
| 49 | 1.3.2.2.2 | 執行上線作業 |  | 2w | 2011-02-18 | 2011-03-03 | 48 | 2011-02-18 | 2011-03-03 | 2w | 150d | 0d | 2 wks | 上線申請書 |
| 50 | 1.3.2.2.3 | 驗證上線結果 |  | 4w | 2011-03-04 | 2011-03-31 | 49 | 2011-03-04 | 2011-03-31 | 4w | 150d | 0d | 4 wks | 上線作業LOG |
| 51 | 1.3.2.2.4 | 修正上線作業程序 |  | 12w | 2011-04-01 | 2011-06-23 | 50 | 2011-04-01 | 2011-06-23 | 12w | 150d | 0d | 12 wks | 更新後的上線作業SOP |
| 52 | 1.3.2.2.5 | 完成上線作業 | milestone | 0d | 2011-06-23 | 2011-06-23 | 51 | 2011-06-23 | 2011-06-23 | 0d | 150d |  | 0 dys | 上線作業LOG |
| 53 | 1.3.2.3 | **教育訓練** |  | 190d | 2011-01-07 | 2011-09-29 |  | 2011-01-07 | 2011-09-29 | 190d | 0d |  | 190 dys |  |
| 54 | 1.3.2.3.1 | 確認教育訓練對象 |  | 2w | 2011-01-07 | 2011-01-20 | 41 | 2011-01-07 | 2011-01-20 | 2w | 0d |  | 2 wks | 教育訓練名單 |
| 55 | 1.3.2.3.2 | 確認教育訓練課程內容 |  | 4w | 2011-01-21 | 2011-02-17 | 54 | 2011-01-21 | 2011-02-17 | 4w | 0d |  | 4 wks | 教育訓練課程大綱 |
| 56 | 1.3.2.3.3 | 製作教育訓練教材 |  | 8w | 2011-02-18 | 2011-04-14 | 55 | 2011-02-18 | 2011-04-14 | 8w | 0d |  | 8 wks | 教育訓練教材 |
| 57 | 1.3.2.3.4 | 安排教育訓練 |  | 2w | 2011-04-15 | 2011-04-28 | 56 | 2011-04-15 | 2011-04-28 | 2w | 0d |  | 2 wks | 教育訓練時程表 |
| 58 | 1.3.2.3.5 | 進行教育訓練 |  | 16w | 2011-04-29 | 2011-08-18 | 57 | 2011-04-29 | 2011-08-18 | 16w | 0d |  | 16 wks | 教育訓練 |
| 59 | 1.3.2.3.6 | 學習成果評量(進行測驗) |  | 4w | 2011-08-19 | 2011-09-15 | 58 | 2011-08-19 | 2011-09-15 | 4w | 0d |  | 4 wks | 測驗結果 |
| 60 | 1.3.2.3.7 | 檢討執行成效 |  | 2w | 2011-09-16 | 2011-09-29 | 59 | 2011-09-16 | 2011-09-29 | 2w | 0d |  | 2 wks | 檢討報告 |
| 61 | 1.3.2.3.8 | 完成教育訓練 | milestone | 0d | 2011-09-29 | 2011-09-29 | 60 | 2011-09-29 | 2011-09-29 | 0d | 0d |  | 0 dys | 完工驗收單、完工報告 |

| ID | WBS | Task | Type | Duration | Start | Finish | Predecessors | Baseline start | Baseline finish | Baseline duration | Total slack | Free slack | Text2 | Text1 |
| --- | --- | --- | --- | --- | --- | --- | --- | --- | --- | --- | --- | --- | --- | --- |
| 62 | 1.3.3 | **系統維護及改善規劃** |  | 60d | 2011-09-30 | 2011-12-22 | 61 | 2011-09-30 | 2011-12-22 | 60d | 0d |  | 60 dys |  |
| 63 | 1.3.3.1 | 問題解答及Q&A製作 |  | 8w | 2011-09-30 | 2011-11-24 |  | 2011-09-30 | 2011-11-24 | 8w | 20d |  | 8 wks | 問題解答及Q&A文件 |
| 64 | 1.3.3.2 | 系統錯誤修正 |  | 12w | 2011-09-30 | 2011-12-22 |  | 2011-09-30 | 2011-12-22 | 12w | 0d |  | 12 wks | 更新後的程式 |
| 65 | 1.3.3.3 | 規劃系統功能修改及新增SOP |  | 2w | 2011-09-30 | 2011-10-13 |  | 2011-09-30 | 2011-10-13 | 2w | 40d | 0d | 2 wks | 系統功能修改及新增作業辦法草案 |
| 66 | 1.3.3.4 | 製作系統功能修改及新增SOP |  | 2w | 2011-10-14 | 2011-10-27 | 65 | 2011-10-14 | 2011-10-27 | 2w | 40d |  | 2 wks | 系統功能修改及新增作業辦法 |
| 67 | 1.4 | **結案階段** |  | 20d | 2011-12-23 | 2012-01-19 |  | 2011-12-23 | 2012-01-19 | 20d | 0d |  | 20 dys |  |
| 68 | 1.4.1 | 製作結案報告書 |  | 4w | 2011-12-23 | 2012-01-19 | 62 | 2011-12-23 | 2012-01-19 | 4w | 0d |  | 4 wks | 結案報告書 |
| 69 | 1.4.2 | 結案報告審核 | milestone | 0d | 2012-01-19 | 2012-01-19 | 68 | 2012-01-19 | 2012-01-19 | 0d | 0d |  | 0 dys | 結案報告審核表 |
