# 080901_R1.0 子專案6-PMO年度工作計畫的製作及執行(Kris)

Schedule from MS Project, 2008-09-05 to 2009-12-31.

## Calendars

- 標準: Mon-Fri 08:00-12:00, 13:00-17:00; Sat-Sun off.

## Schedule

| ID | WBS | Task | Type | Duration | Start | Finish | Predecessors | Total slack | Free slack | Constraint |
| --- | --- | --- | --- | --- | --- | --- | --- | --- | --- | --- |
| 1 | 1 | **年度工作計畫的製作及執行** |  | 344d | 2008-09-05 | 2009-12-31 |  | 0d |  |  |
| 2 | 1.1 | **撰寫 年度工作計畫** |  | 45d | 2008-09-05 | 2008-11-06 |  | 49d |  |  |
| 3 | 1.1.1 | 撰寫初稿 |  | 4w | 2008-09-05 | 2008-10-02 |  | 49d | 0d |  |
| 4 | 1.1.2 | 審校 |  | 1w | 2008-10-03 | 2008-10-09 | 3 | 49d | 0d |  |
| 5 | 1.1.3 | 複稿完成 |  | 2w | 2008-10-10 | 2008-10-23 | 4 | 49d | 0d |  |
| 6 | 1.1.4 | 校稿 |  | 1w | 2008-10-24 | 2008-10-30 | 5 | 49d | 0d |  |
| 7 | 1.1.5 | 完搞 |  | 1w | 2008-10-31 | 2008-11-06 | 6 | 49d | 0d |  |
| 8 | 1.2 | PMO人員招募及訓練 |  | 16w | 2008-11-07 | 2009-02-26 | 7 | 219d |  |  |
| 9 | 1.3 | **審核及啟動年度工作計畫** |  | 10d | 2008-11-07 | 2008-11-20 |  | 49d |  |  |
| 10 | 1.3.1 | 審核年度工作計畫 |  | 1w | 2008-11-07 | 2008-11-13 | 7 | 49d | 0d |  |
| 11 | 1.3.2 | 製作細部時程計畫 |  | 1w | 2008-11-14 | 2008-11-20 | 10 | 49d | 0d |  |
| 12 | 1.3.3 | Kick-off Meeting | milestone | 0d | 2008-11-20 | 2008-11-20 | 11 | 49d | 29d |  |
| 13 | 1.4 | **執行及控管年度工作計畫** |  | 255d | 2009-01-01 | 2009-12-24 |  | 5d |  |  |
| 14 | 1.4.1 | **第一季工作執行** |  | 65d | 2009-01-01 | 2009-04-02 | 12 | 15d |  |  |
| 15 | 1.4.1.1 | 製作細部工作計畫 |  | 1w | 2009-01-01 | 2009-01-07 |  | 20d | 0d | start no earlier than 2009-01-01 |
| 16 | 1.4.1.2 | 執行及控管 |  | 11w | 2009-01-08 | 2009-03-25 | 15 | 20d | 5d |  |
| 17 | 1.4.1.3 | 第一季工作檢討會議 | milestone | 0d | 2009-04-02 | 2009-04-02 | 16 | 15d | 0d | start no earlier than 2009-04-02 |
| 18 | 1.4.2 | **第二季工作執行** |  | 65d | 2009-04-02 | 2009-07-02 | 17 | 10d |  |  |
| 19 | 1.4.2.1 | 製作細部工作計畫 |  | 1w | 2009-04-02 | 2009-04-08 |  | 15d | 0d |  |
| 20 | 1.4.2.2 | 執行及控管 |  | 11w | 2009-04-09 | 2009-06-24 | 19 | 15d | 5d |  |
| 21 | 1.4.2.3 | 第二季工作檢討會議 | milestone | 0d | 2009-07-02 | 2009-07-02 | 20 | 10d | 0d | start no earlier than 2009-07-02 |
| 22 | 1.4.3 | **第三季工作執行及控管** |  | 65d | 2009-07-02 | 2009-10-01 | 21 | 5d | 0d |  |
| 23 | 1.4.3.1 | 製作細部工作計畫 |  | 1w | 2009-07-02 | 2009-07-08 |  | 10d | 0d |  |
| 24 | 1.4.3.2 | 執行及控管 |  | 11w | 2009-07-09 | 2009-09-23 | 23 | 10d | 5d |  |
| 25 | 1.4.3.3 | 第三季工作檢討會議 | milestone | 0d | 2009-10-01 | 2009-10-01 | 24 | 5d | 0d | start no earlier than 2009-10-01 |

| ID | WBS | Task | Type | Duration | Start | Finish | Predecessors | Total slack | Free slack | Constraint |
| --- | --- | --- | --- | --- | --- | --- | --- | --- | --- | --- |
| 26 | 1.4.4 | **第四季工作執行及控管** |  | 60d | 2009-10-01 | 2009-12-24 | 25 | 5d |  |  |
| 27 | 1.4.4.1 | 製作細部工作計畫 |  | 1w | 2009-10-01 | 2009-10-07 |  | 5d | 0d |  |
| 28 | 1.4.4.2 | 執行及控管 |  | 11w | 2009-10-08 | 2009-12-23 | 27 | 5d | 0d |  |
| 29 | 1.4.4.3 | 第四季工作檢討會議 | milestone | 0d | 2009-12-24 | 2009-12-24 | 28 | 5d |  | start no earlier than 2009-12-24 |
| 30 | 1.5 | **年度結束檢討及報告** |  | 65d | 2009-10-01 | 2009-12-31 |  | 0d |  |  |
| 31 | 1.5.1 | 撰寫下年度工作計畫 |  | 8w | 2009-10-01 | 2009-11-25 | 22 | 5d | 0d |  |
| 32 | 1.5.2 | 撰寫年度工作結束報告書 |  | 4w | 2009-11-26 | 2009-12-23 | 31 | 5d |  |  |
| 33 | 1.5.3 | 召開年度工作執行成效檢討會議 | milestone | 0d | 2009-12-31 | 2009-12-31 | 32 | 0d |  | start no earlier than 2009-12-31 |
