# 飾品銷售網站成立及架設

Schedule from MS Project, 2010-01-01 to 2010-07-29.
yt

## Calendars

- 標準: Mon-Fri 08:00-12:00, 13:00-17:00; Sat-Sun off.

## Schedule

| ID | WBS | Task | Duration | Start | Finish | Predecessors | Total slack | Free slack |
| --- | --- | --- | --- | --- | --- | --- | --- | --- |
| 1 | 11 | **成立公司** | 63d? | 2010-01-01 | 2010-03-30 |  | 0d |  |
| 2 | 11.1 | **集資** | 30d | 2010-01-01 | 2010-02-11 |  | 0d |  |
| 3 | 11.1.1 | 計畫書 (公司願景 /定位 | 10d | 2010-01-01 | 2010-01-14 |  | 0d |  |
| 4 | 11.1.2 | BP (Business Plan) | 10d | 2010-01-15 | 2010-01-28 | 3 | 0d |  |
| 5 | 11.1.3 | 找投資者 | 10d | 2010-01-29 | 2010-02-11 | 4 | 0d |  |
| 6 | 11.2 | **準備申請文件** | 7d? | 2010-02-12 | 2010-02-22 |  | 0d |  |
| 7 | 11.2.1 | 決定公司名稱 | 1d? | 2010-02-12 | 2010-02-12 | 5 | 0d |  |
| 8 | 11.2.2 | 公司申請書 | 1d? | 2010-02-15 | 2010-02-15 | 7 | 0d |  |
| 9 | 11.2.3 | 公司章程 | 5d | 2010-02-16 | 2010-02-22 | 8 | 0d |  |
| 10 | 11.3 | **公司申請及整理** | 26d | 2010-02-23 | 2010-03-30 |  | 0d |  |
| 11 | 11.3.1 | 申請公司執照 / 申請營利事業登記證 | 10d | 2010-02-23 | 2010-03-08 | 9 | 0d |  |
| 12 | 11.3.2 | 公司地點確認 | 1d | 2010-03-09 | 2010-03-09 | 11 | 0d |  |
| 13 | 11.3.3 | 公司內部整理 | 10d | 2010-03-10 | 2010-03-23 | 12 | 0d |  |
| 14 | 11.3.4 | 完成辦公室擺設 | 5d | 2010-03-24 | 2010-03-30 | 13 | 0d |  |
| 15 | 12 | **網站環境架設** | 37d? | 2010-03-31 | 2010-05-20 |  | 0d |  |
| 16 | 12.1 | **硬體** | 8d? | 2010-03-31 | 2010-04-09 |  | 0d |  |
| 17 | 12.1.1 | **尋找網站供應商部分** | 8d | 2010-03-31 | 2010-04-09 |  | 79d |  |
| 18 | 12.1.1.1 | 評估網頁空間流量需求 | 7d | 2010-03-31 | 2010-04-08 | 14 | 80d |  |
| 19 | 12.1.1.2 | 尋找合適網頁hosting 供應商 | 7d | 2010-03-31 | 2010-04-08 | 14 | 79d | 0d |
| 20 | 12.1.1.3 | 比較各供應商所提供之方案並決定供應商 | 1d | 2010-04-09 | 2010-04-09 | 19 | 79d |  |
| 21 | 12.1.2 | **架站部分** | 2d? | 2010-03-31 | 2010-04-01 |  | 0d |  |
| 22 | 12.1.2.1 | 申請 domain name | 1d? | 2010-03-31 | 2010-03-31 | 14 | 0d |  |
| 23 | 12.1.2.2 | 設定 DNS | 1d? | 2010-04-01 | 2010-04-01 | 22 | 0d |  |
| 24 | 12.2 | **軟體** | 35d? | 2010-04-02 | 2010-05-20 |  | 0d |  |
| 25 | 12.2.1 | **決定業系統** | 5d? | 2010-04-02 | 2010-04-08 |  | 0d |  |
| 26 | 12.2.1.1 | **Windows server 2003 評估** | 5d? | 2010-04-02 | 2010-04-08 |  | 80d |  |
| 27 | 12.2.1.1.1 | 評估操控性 | 1d? | 2010-04-02 | 2010-04-02 | 23 | 80d | 0d |
| 28 | 12.2.1.1.2 | 評估硬體需求 | 1d? | 2010-04-05 | 2010-04-05 | 27 | 80d | 0d |
| 29 | 12.2.1.1.3 | 評估與其它軟、硬體相容性 | 1d? | 2010-04-06 | 2010-04-06 | 28 | 80d | 0d |
| 30 | 12.2.1.1.4 | 評估購置成本 | 1d? | 2010-04-07 | 2010-04-07 | 29 | 80d | 0d |
| 31 | 12.2.1.1.5 | 評估售後服務 | 1d? | 2010-04-08 | 2010-04-08 | 30 | 80d |  |

| ID | WBS | Task | Duration | Start | Finish | Predecessors | Total slack | Free slack |
| --- | --- | --- | --- | --- | --- | --- | --- | --- |
| 32 | 12.2.1.2 | **Windows server 2000 評估** | 5d? | 2010-04-02 | 2010-04-08 |  | 80d |  |
| 33 | 12.2.1.2.1 | 評估操控性 | 1d? | 2010-04-02 | 2010-04-02 | 23 | 80d | 0d |
| 34 | 12.2.1.2.2 | 評估硬體需求 | 1d? | 2010-04-05 | 2010-04-05 | 33 | 80d | 0d |
| 35 | 12.2.1.2.3 | 評估與其它軟、硬體相容性 | 1d? | 2010-04-06 | 2010-04-06 | 34 | 80d | 0d |
| 36 | 12.2.1.2.4 | 評估購置成本 | 1d? | 2010-04-07 | 2010-04-07 | 35 | 80d | 0d |
| 37 | 12.2.1.2.5 | 評估售後服務 | 1d? | 2010-04-08 | 2010-04-08 | 36 | 80d |  |
| 38 | 12.2.1.3 | **Linux評估** | 5d? | 2010-04-02 | 2010-04-08 |  | 0d |  |
| 39 | 12.2.1.3.1 | 評估操控性 | 1d? | 2010-04-02 | 2010-04-02 | 23 | 0d |  |
| 40 | 12.2.1.3.2 | 評估硬體需求 | 1d? | 2010-04-05 | 2010-04-05 | 39 | 0d |  |
| 41 | 12.2.1.3.3 | 評估與其它軟、硬體相容性 | 1d? | 2010-04-06 | 2010-04-06 | 40 | 0d |  |
| 42 | 12.2.1.3.4 | 評估購置成本 | 1d? | 2010-04-07 | 2010-04-07 | 41 | 0d |  |
| 43 | 12.2.1.3.5 | 評估售後服務 | 1d? | 2010-04-08 | 2010-04-08 | 42 | 0d |  |
| 44 | 12.2.2 | **管理平台** | 15d | 2010-04-09 | 2010-04-29 |  | 0d |  |
| 45 | 12.2.2.1 | 建立檔案編修平台 | 5d | 2010-04-09 | 2010-04-15 | 43 | 0d |  |
| 46 | 12.2.2.2 | 建立帳務系統(paypal即可) | 5d | 2010-04-16 | 2010-04-22 | 45 | 0d |  |
| 47 | 12.2.2.3 | 建立使用者管理介面 | 5d | 2010-04-23 | 2010-04-29 | 46 | 0d |  |
| 48 | 12.2.12 | **美編** | 15d | 2010-04-30 | 2010-05-20 |  | 0d |  |
| 49 | 12.2.12.4 | **頁面設計外包商** | 15d | 2010-04-30 | 2010-05-20 |  | 0d |  |
| 50 | 12.2.12.4.7 | 美觀性設計 | 5d | 2010-04-30 | 2010-05-06 | 47 | 0d |  |
| 51 | 12.2.12.4.8 | 售後服務設計 | 5d | 2010-05-07 | 2010-05-13 | 50 | 0d |  |
| 52 | 12.2.12.4.9 | 頁面整合 | 5d | 2010-05-14 | 2010-05-20 | 51 | 0d |  |
| 53 | 14 | **Business model** | 87d? | 2010-03-31 | 2010-07-29 |  | 0d |  |
| 54 | 14.1 | **廣告** | 50d | 2010-05-21 | 2010-07-29 |  | 0d |  |
| 55 | 14.1.1 | 上網登廣告 | 5d | 2010-05-21 | 2010-05-27 | 52 | 45d |  |
| 56 | 14.1.2 | 舉辦飾品DIY學習會(收當日學習費 邀請網內人氣最佳的廣告商 來當講師) | 10d | 2010-07-16 | 2010-07-29 | 65FS+30d | 0d |  |

| ID | WBS | Task | Duration | Start | Finish | Predecessors | Total slack | Free slack |
| --- | --- | --- | --- | --- | --- | --- | --- | --- |
| 57 | 14.3 | **Recruit customers** | 30d | 2010-03-31 | 2010-05-11 |  | 57d |  |
| 58 | 14.3.1 | 到台北、台中、高雄有擺地攤的地方去遊說飾品地攤業者 | 30d | 2010-03-31 | 2010-05-11 | 14 | 57d |  |
| 59 | 14.3.2 | 上網找飾品DIY教學的地方 | 15d | 2010-03-31 | 2010-04-20 | 14 | 72d |  |
| 60 | 14.3.3 | 詢問救國團 | 5d | 2010-03-31 | 2010-04-06 | 14 | 82d |  |
| 61 | 14.3.4 | 上拍賣(YAHOO、eBay)訪站找飾品DIY的業者 | 5d | 2010-03-31 | 2010-04-06 | 14 | 82d |  |
| 62 | 14.5 | **Promotion** | 33d | 2010-05-21 | 2010-07-06 |  | 0d |  |
| 63 | 14.5.1 | 月租費用說明 | 5d | 2010-05-21 | 2010-05-27 | 52 | 43d | 0d |
| 64 | 14.5.2 | 每月流量說明及流覽者之趨向 | 3d | 2010-07-02 | 2010-07-06 | 52FS+30d | 17d |  |
| 65 | 14.5.3 | 網站為互動式 消費者可以描繪出自己想要的飾品 | 10d | 2010-05-21 | 2010-06-03 | 52 | 0d |  |
| 66 | 14.5.4 | 有飾品討論區 | 10d | 2010-05-21 | 2010-06-03 | 52 | 40d |  |
| 67 | 14.7 | **Accounting** | 2d? | 2010-05-28 | 2010-05-31 |  | 43d |  |
| 68 | 14.7.1 | 管銷費月登記 (架設費月 交通費 交劑費) | 1d? | 2010-05-28 | 2010-05-28 | 63 | 43d | 0d |
| 69 | 14.7.2 | 月租收入登記 | 1d? | 2010-05-31 | 2010-05-31 | 68 | 43d |  |
| 70 | 16 | 結案 | 1d? | 2010-01-01 | 2010-01-01 |  | 149d |  |
