# CHT_WBSchart

Schedule from MS Project, 2007-11-13 to 2008-01-01.

## Calendars

- 標準: Mon-Fri 08:00-12:00, 13:00-17:00; Sat-Sun off.

## Schedule

| ID | WBS | Task | Duration | Start | Finish | Predecessors | Total slack | Free slack | Constraint |
| --- | --- | --- | --- | --- | --- | --- | --- | --- | --- |
| 1 | 1 | **網路設備系統汰換專案** | 36d? | 2007-11-13 | 2008-01-01 |  | 0d |  |  |
| 2 | 1.1 | **準備工作** | 9d | 2007-11-13 | 2007-11-23 |  | 27d |  |  |
| 3 | 1.1.1 | **專案起始會議** | 3d | 2007-11-13 | 2007-11-15 |  | 33d |  |  |
| 4 | 1.1.1.1 | 標案內容檢閱 | 2d | 2007-11-13 | 2007-11-14 |  | 33d | 0d | finish no earlier than 2007-11-14 |
| 5 | 1.1.1.2 | 會議簡報 | 1d | 2007-11-15 | 2007-11-15 | 4 | 33d |  |  |
| 6 | 1.1.2 | **準備平台軟體** | 7d | 2007-11-15 | 2007-11-23 |  | 27d |  |  |
| 7 | 1.1.2.1 | 新系統硬體平台準備 | 1d | 2007-11-15 | 2007-11-15 |  | 33d |  |  |
| 8 | 1.1.2.2 | 軟體系統準備 | 7d | 2007-11-15 | 2007-11-23 |  | 27d |  | finish no earlier than 2007-11-23 |
| 9 | 1.1.3 | **安裝空間準備** | 5d | 2007-11-19 | 2007-11-23 |  | 27d |  |  |
| 10 | 1.1.3.1 | 機櫃準備 | 1d | 2007-11-19 | 2007-11-19 |  | 30d | 2d | start no earlier than 2007-11-19 |
| 11 | 1.1.3.2 | 電力佈線 | 1d | 2007-11-22 | 2007-11-22 | 10 | 28d |  | start no earlier than 2007-11-22 |
| 12 | 1.1.3.3 | 網路佈線 | 1d | 2007-11-23 | 2007-11-23 | 10 | 27d |  | start no earlier than 2007-11-23 |
| 13 | 1.1.3.4 | 相關設備安裝 | 1d | 2007-11-23 | 2007-11-23 | 10 | 27d |  | start no earlier than 2007-11-23 |
| 14 | 1.1.4 | **安裝規劃** | 6d | 2007-11-16 | 2007-11-23 |  | 27d |  |  |
| 15 | 1.1.4.1 | 需求討論 | 4d | 2007-11-16 | 2007-11-21 |  | 29d |  | start no earlier than 2007-11-16 |
| 16 | 1.1.4.2 | 安裝步驟分析與計畫 | 5d | 2007-11-16 | 2007-11-22 |  | 27d | 0d | start no earlier than 2007-11-16 |
| 17 | 1.1.4.3 | 客戶確認計畫 | 1d | 2007-11-23 | 2007-11-23 | 16 | 27d |  | start no earlier than 2007-11-23 |
| 18 | 1.2 | **交貨工作** | 12d? | 2007-11-13 | 2007-11-28 |  | 24d |  |  |
| 19 | 1.2.1 | **備貨** | 9d | 2007-11-13 | 2007-11-23 |  | 24d | 0d |  |
| 20 | 1.2.1.1 | A系統設備 | 9d | 2007-11-13 | 2007-11-23 |  | 24d |  | finish no earlier than 2007-11-23 |
| 21 | 1.2.1.2 | B系統設備 | 9d | 2007-11-13 | 2007-11-23 |  | 24d |  | finish no earlier than 2007-11-23 |
| 22 | 1.2.2 | **交貨點收** | 3d? | 2007-11-26 | 2007-11-28 | 19 | 24d |  |  |
| 23 | 1.2.2.1 | A地點交貨 | 1d | 2007-11-26 | 2007-11-26 |  | 24d | 0d | start no earlier than 2007-11-26 |
| 24 | 1.2.2.2 | B地點交貨 | 1d? | 2007-11-27 | 2007-11-27 | 23 | 24d | 0d |  |
| 25 | 1.2.2.3 | 交貨點收單確認 | 1d | 2007-11-28 | 2007-11-28 | 24 | 24d |  | start no earlier than 2007-11-26 |

| ID | WBS | Task | Duration | Start | Finish | Predecessors | Total slack | Free slack | Constraint |
| --- | --- | --- | --- | --- | --- | --- | --- | --- | --- |
| 26 | 1.3 | **安裝工作** | 14d | 2007-11-27 | 2007-12-14 |  | 2d | 0d |  |
| 27 | 1.3.1 | **A設備** | 4d | 2007-11-27 | 2007-11-30 |  | 12d |  |  |
| 28 | 1.3.1.1 | Switch安裝 | 2d | 2007-11-27 | 2007-11-28 |  | 12d | 0d | start no earlier than 2007-11-27 |
| 29 | 1.3.1.2 | VoIP Gateway安裝 | 2d | 2007-11-29 | 2007-11-30 | 28 | 12d |  | start no earlier than 2007-11-29 |
| 30 | 1.3.2 | **B設備** | 5.5d | 2007-11-27 | 2007-12-04 |  | 2d | 0d |  |
| 31 | 1.3.2.1 | 伺服器安裝 | 5.5d | 2007-11-27 | 2007-12-04 |  | 2d | 0d | start no earlier than 2007-11-27 |
| 32 | 1.3.2.2 | Storage安裝 | 4d | 2007-11-27 | 2007-11-30 |  | 3.5d | 1.5d | start no earlier than 2007-11-27 |
| 33 | 1.3.3 | **系統軟體** | 8.5d | 2007-12-04 | 2007-12-14 | 30 | 2d | 0d |  |
| 34 | 1.3.3.1 | Cluster安裝 | 2d | 2007-12-04 | 2007-12-06 | 31, 32 | 2d | 0d | start no earlier than 2007-12-03 |
| 35 | 1.3.3.2 | 各元件安裝 | 5d | 2007-12-06 | 2007-12-13 | 34 | 2d | 0d | start no earlier than 2007-12-05 |
| 36 | 1.3.3.3 | 功能測試 | 1.5d | 2007-12-13 | 2007-12-14 | 35 | 2d |  | start no earlier than 2007-12-13 |
| 37 | 1.4 | **汰換工作** | 10d | 2007-12-17 | 2007-12-28 | 33, 26 | 2d |  |  |
| 38 | 1.4.1 | 設定原有系統資料 | 2d | 2007-12-17 | 2007-12-18 |  | 2d | 0d | start no earlier than 2007-12-17 |
| 39 | 1.4.2 | 切換前測試 | 2d | 2007-12-19 | 2007-12-20 | 38 | 2d | 0d | start no earlier than 2007-12-19 |
| 40 | 1.4.3 | 執行切換工作 | 1d | 2007-12-21 | 2007-12-21 | 39 | 2d | 0d | start no earlier than 2007-12-21 |
| 41 | 1.4.4 | 切換後測試 | 3d | 2007-12-24 | 2007-12-26 | 40 | 2d | 0d | start no earlier than 2007-12-22 |
| 42 | 1.4.5 | 移除原有設備 | 2d | 2007-12-27 | 2007-12-28 | 41 | 2d |  | start no earlier than 2007-12-27 |
| 43 | 1.4.6 | 汰換完成確認 | 1d | 2007-12-28 | 2007-12-28 |  | 0d |  | start no earlier than 2007-12-28 |
| 44 | 1.5 | **結案工作** | 2d? | 2007-12-31 | 2008-01-01 |  | 0d |  |  |
| 45 | 1.5.1 | 結案文件整理歸檔 | 1d? | 2007-12-31 | 2007-12-31 | 43 | 0d |  |  |
| 46 | 1.5.2 | 結案檢討及報告 | 1d? | 2008-01-01 | 2008-01-01 | 45 | 0d |  |  |
