# 專案1

Schedule from MS Project, 2004-05-31 to 2005-03-18.
home

## Calendars

- 標準: Mon-Fri 08:00-12:00, 13:00-17:00; Sat-Sun off.

## Resources

| Resource |
| --- |
| 專案經理 |
| Key user |
| 副總經理 |
| 廠長 |
| 副廠長 |
| 系統分析師 |
| 程式設計師 |
| 經理 |
| 副理 |
| 採購人員 |

## Schedule

| ID | WBS | Task | Type | Duration | Start | Finish | Predecessors | Total slack | Free slack | Constraint | Deadline |
| --- | --- | --- | --- | --- | --- | --- | --- | --- | --- | --- | --- |
| 1 | F | **製造資訊系統導入專案計劃** |  | 209.5d? | 2004-05-31 | 2005-03-18 |  | -1d | 0d |  |  |
| 2 | F.1 | 指派專案經理 |  | 1d? | 2004-05-31 | 2004-06-01 |  | -1d | 0d | start no later than 2004-06-21 |  |
| 3 | F.2 | 專案小組成立 |  | 8d | 2004-06-01 | 2004-06-11 | 2 | 3.5d | 0d |  |  |
| 4 | F.4 | 建立project charter |  | 5d | 2004-06-11 | 2004-06-18 | 3 | 3.5d | 0d |  |  |
| 5 | F.6 | 送呈核准 |  | 5d | 2004-06-18 | 2004-06-25 | 4 | 3.5d |  | start no later than 2004-06-25 |  |
| 6 | F.7 | 專案正式成立 | milestone | 1d? | 2004-07-01 | 2004-07-01 | 5 | 0d |  | must finish on 2004-07-01 | 2004-07-01 |
| 7 | F.8 | **專案管理與控制** |  | 1d? | 2004-07-02 | 2004-07-02 |  | 0d |  |  |  |
| 8 | F.8.2 | 專案起始會議(kick-off meeting) | milestone | 1d? | 2004-07-02 | 2004-07-02 | 6 | 0d |  | start no later than 2004-07-02 |  |
| 9 | F.9 | **解決方案分析** |  | 54.5d | 2004-06-01 | 2004-08-16 |  | -1d | 0d |  |  |
| 10 | F.9.10 | **製造廠相關資料收集** |  | 15d | 2004-06-01 | 2004-06-22 | 2 | -1d | 0d |  |  |
| 11 | F.9.10.5 | 產線與產能規劃資料 |  | 12d | 2004-06-01 | 2004-06-17 |  | 2d |  | start no later than 2004-07-02 |  |
| 12 | F.9.10.6 | 作業模式需求資料 |  | 15d | 2004-06-01 | 2004-06-22 |  | -1d | 0d | start no later than 2004-07-02 |  |
| 13 | F.9.10.7 | 管理性指標與報表需求 |  | 10d | 2004-06-01 | 2004-06-15 |  | 4d |  | start no later than 2004-07-02 |  |
| 14 | F.9.11 | 資料研讀與修正 |  | 8d | 2004-06-22 | 2004-07-02 | 10 | -1d | 0d | start no later than 2004-07-02 |  |
| 15 | F.9.12 | **第一階段方案選擇** |  | 9.5d | 2004-07-02 | 2004-07-15 |  | -0.5d | 0d |  |  |
| 16 | F.9.12.6 | 遞交評估建議報告 |  | 5d | 2004-07-02 | 2004-07-08 | 14 | -0.5d | 0d | start no later than 2004-07-02 |  |
| 17 | F.9.12.7 | 意向調查與評估 |  | 4d | 2004-07-09 | 2004-07-14 | 16 | -0.5d | 0d | start no later than 2004-07-09 |  |
| 18 | F.9.12.8 | 確認解決方案建立方向 | milestone | 0.5d | 2004-07-14 | 2004-07-15 | 17 | -0.5d | 0d | start no later than 2004-07-14 |  |
| 19 | F.9.13 | **邀商與方案評估** |  | 21d | 2004-07-15 | 2004-08-12 | 18 | 0d |  |  |  |
| 20 | F.9.13.4 | 遴選系統廠商 |  | 3d | 2004-07-15 | 2004-07-19 |  | -0.5d | 0d | start no later than 2004-07-15 |  |
| 21 | F.9.13.5 | 撰寫RFP |  | 4d | 2004-07-19 | 2004-07-23 | 20 | 0d |  | start no later than 2004-07-19 |  |
| 22 | F.9.13.6 | 系統廠商建議書審核 |  | 8d | 2004-07-23 | 2004-08-04 | 21 | 0d |  | start no later than 2004-07-23 |  |
| 23 | F.9.13.7 | 議價 |  | 3d | 2004-08-04 | 2004-08-09 | 22 | 0d |  | start no later than 2004-08-04 |  |
| 24 | F.9.13.8 | 評比與方案決定 |  | 3d | 2004-08-09 | 2004-08-12 | 23 | 0d |  | start no later than 2004-08-09 |  |
| 25 | F.9.14 | 核准方案 | milestone | 2d | 2004-08-12 | 2004-08-16 | 24 | 0d |  | start no later than 2004-08-12 |  |

| ID | WBS | Task | Duration | Start | Finish | Predecessors | Total slack | Constraint |
| --- | --- | --- | --- | --- | --- | --- | --- | --- |
| 26 | F.10 | **採購作業階段** | 107d? | 2004-08-17 | 2005-01-12 |  | 0d |  |
| 27 | F.10.8 | **請購作業** | 8d | 2004-08-17 | 2004-08-26 |  | 0d |  |
| 28 | F.10.8.5 | 採購規範書準備 | 4d | 2004-08-17 | 2004-08-20 | 25 | 0d | start no earlier than 2004-08-16 |
| 29 | F.10.8.6 | 開立請購單 | 2d | 2004-08-23 | 2004-08-24 | 28 | 0d | start no earlier than 2004-08-20 |
| 30 | F.10.8.7 | 請購簽核流程執行 | 2d | 2004-08-24 | 2004-08-26 | 29 | 0d | start no later than 2004-08-24 |
| 31 | F.10.9 | **採購作業階段** | 23d? | 2004-08-27 | 2004-09-28 | 30 | 0d |  |
| 32 | F.10.9.5 | 議價與付款條件磋商 | 15d | 2004-08-27 | 2004-09-16 |  | 0d | as late as possible |
| 33 | F.10.9.6 | 合約簽訂 | 7d | 2004-09-17 | 2004-09-27 | 32 | 0d | as late as possible |
| 34 | F.10.9.7 | 發出正式採購單 | 1d? | 2004-09-28 | 2004-09-28 | 33 | 0d | as late as possible |
| 35 | F.10.10 | **設備交付** | 76d? | 2004-09-29 | 2005-01-12 | 34 | 0d |  |
| 36 | F.10.10.5 | **硬體** | 70d? | 2004-09-29 | 2005-01-04 |  | 0d |  |
| 37 | F.10.10.5.3 | 主機伺服器 | 70d | 2004-09-29 | 2005-01-04 |  | 0d | start no earlier than 2004-08-30 |
| 38 | F.10.10.5.4 | PC | 1d? | 2004-12-31 | 2004-12-31 |  | 0d | as late as possible |
| 39 | F.10.10.6 | **軟體** | 76d? | 2004-09-29 | 2005-01-12 |  | 0d |  |
| 40 | F.10.10.6.3 | 資料庫管理系統 | 1d? | 2004-09-29 | 2004-09-30 |  | 0d | as late as possible |
| 41 | F.10.10.6.4 | 訊息佇列中介軟體 | 1d? | 2004-09-29 | 2004-09-29 |  | 0d | as late as possible |
| 42 | F.10.10.6.5 | MES系統 | 1d? | 2005-01-12 | 2005-01-12 | 53 | 0d | as late as possible |
| 43 | F.11 | **系統客製開發作業** | 75d | 2004-09-29 | 2005-01-11 |  | 0d |  |
| 44 | F.11.9 | **需求分析** | 8d | 2004-09-29 | 2004-10-08 | 34 | 0d |  |
| 45 | F.11.9.3 | 需求規格訪談 | 8d | 2004-09-29 | 2004-10-08 |  | 0d | as late as possible |
| 46 | F.11.9.4 | 規格確認 | 5d | 2004-10-04 | 2004-10-08 |  | 0d | as late as possible |
| 47 | F.11.10 | **概念模型設計階段** | 5d | 2004-10-11 | 2004-10-15 | 45 | 0d |  |
| 48 | F.11.10.3 | 系統模型提出與審核 | 5d | 2004-10-11 | 2004-10-15 |  | 0d | as late as possible |
| 49 | F.11.10.4 | 確認規格 | 5d | 2004-10-11 | 2004-10-15 |  | 0d | as late as possible |

| ID | WBS | Task | Type | Duration | Start | Finish | Predecessors | Total slack | Constraint |
| --- | --- | --- | --- | --- | --- | --- | --- | --- | --- |
| 50 | F.11.11 | **開發設計階段** |  | 60d | 2004-10-18 | 2005-01-07 | 49 | 0d |  |
| 51 | F.11.11.3 | 程式撰寫 |  | 60d | 2004-10-18 | 2005-01-07 |  | 0d | as late as possible |
| 52 | F.11.11.4 | 初步測試驗證 |  | 15d | 2004-12-20 | 2005-01-07 |  | 0d | as late as possible |
| 53 | F.11.12 | 系統軟體交付 |  | 2d | 2005-01-10 | 2005-01-11 | 50 | 0d | as late as possible |
| 54 | F.12 | **環境設定與安裝** |  | 166.5d? | 2004-05-31 | 2005-01-18 |  | 0d |  |
| 55 | F.12.10 | 機房環境架設確認 |  | 2d? | 2004-05-31 | 2004-06-02 |  | 154.5d |  |
| 56 | F.12.11 | **硬體** |  | 12d? | 2005-01-03 | 2005-01-18 |  | 0d |  |
| 57 | F.12.11.14 | **伺服器** |  | 10d | 2005-01-05 | 2005-01-18 |  | 0d |  |
| 58 | F.12.11.14.6 | 燒機測試 |  | 5d | 2005-01-05 | 2005-01-11 | 55, 37 | 0d | start no earlier than 2004-12-28 |
| 59 | F.12.11.14.7 | 作業系統安裝及驗證 |  | 3d | 2005-01-12 | 2005-01-14 | 58 | 0d |  |
| 60 | F.12.11.14.8 | 網路作業功能測試 |  | 2d | 2005-01-17 | 2005-01-18 | 59 | 0d | as late as possible |
| 61 | F.12.11.15 | **操作PC** |  | 2d? | 2005-01-03 | 2005-01-04 |  | 0d |  |
| 62 | F.12.11.15.9 | 確認PC數量 |  | 1d? | 2005-01-03 | 2005-01-03 | 38 | 0d | start no earlier than 2005-01-03 |
| 63 | F.12.11.15.10 | 確認部署位置圖 |  | 1d? | 2005-01-04 | 2005-01-04 | 62 | 0d | start no earlier than 2005-01-04 |
| 64 | F.12.11.15.11 | **系統安裝及測試** |  | 1d? | 2005-01-03 | 2005-01-03 |  | 0d |  |
| 65 | F.12.11.15.11.1 | Seed PC製作 |  | 1d? | 2005-01-03 | 2005-01-03 |  | 0d | as late as possible |
| 66 | F.12.11.15.11.2 | 大量複製 |  | 1d? | 2005-01-03 | 2005-01-03 |  | 0d | as late as possible |
| 67 | F.12.11.15.12 | 發行至指定位置 |  | 1d? | 2005-01-04 | 2005-01-04 | 64 | 0d | as late as possible |
| 68 | F.12.12 | **軟體** |  | 25d? | 2004-09-29 | 2004-11-03 |  | 0d |  |
| 69 | F.12.12.1 | **安裝-測試暨教育訓練環境** |  | 2d? | 2004-09-29 | 2004-10-01 |  | 0d |  |
| 70 | F.12.12.1.1 | 資料庫軟體 |  | 1d? | 2004-09-30 | 2004-10-01 | 40 | 0d | as late as possible |
| 71 | F.12.12.1.2 | 訊息佇列中介層系統 |  | 1.5d | 2004-09-30 | 2004-10-01 | 41 | 0d | as late as possible |
| 72 | F.12.12.1.3 | GUI Client軟體自動安裝伺服器 |  | 1d? | 2004-09-30 | 2004-10-01 |  | 0d | as late as possible |
| 73 | F.12.12.1.4 | **MES-測試環境** |  | 2d? | 2004-09-29 | 2004-10-01 |  | 0d |  |
| 74 | F.12.12.1.4.1 | 建置資料庫空間 |  | 1d? | 2004-09-30 | 2004-10-01 |  | 0d | as late as possible |
| 75 | F.12.12.1.4.2 | Table & index & Stored procedure |  | 1d? | 2004-09-30 | 2004-10-01 |  | 0d | as late as possible |
| 76 | F.12.12.1.4.3 | MES伺服層 |  | 2d | 2004-09-29 | 2004-10-01 |  | 0d | as late as possible |
| 77 | F.12.12.2 | Integration Test |  | 5d | 2004-10-01 | 2004-10-08 | 69 | 0d | as late as possible |
| 78 | F.12.12.3 | 狀態確認 | milestone | 1d? | 2004-10-08 | 2004-10-11 | 77 | 0d | as late as possible |

| ID | WBS | Task | Type | Duration | Start | Finish | Predecessors | Total slack | Free slack | Constraint |
| --- | --- | --- | --- | --- | --- | --- | --- | --- | --- | --- |
| 79 | F.12.12.4 | **安裝-正式生產環境** |  | 2d? | 2004-10-22 | 2004-10-26 | 78 | 0d |  |  |
| 80 | F.12.12.4.1 | 資料庫軟體 |  | 1d? | 2004-10-25 | 2004-10-26 |  | 0d |  | as late as possible |
| 81 | F.12.12.4.2 | 訊息佇列中介層系統 |  | 1.5d | 2004-10-25 | 2004-10-26 |  | 0d |  | as late as possible |
| 82 | F.12.12.4.3 | GUI Client軟體自動安裝伺服器 |  | 1d? | 2004-10-25 | 2004-10-26 |  | 0d |  | as late as possible |
| 83 | F.12.12.4.4 | **MES-測試環境** |  | 2d? | 2004-10-22 | 2004-10-26 |  | 0d |  |  |
| 84 | F.12.12.4.4.1 | 建置資料庫空間 |  | 1.5d | 2004-10-25 | 2004-10-26 |  | 0d |  | as late as possible |
| 85 | F.12.12.4.4.2 | Table & index & Stored procedure |  | 1d? | 2004-10-25 | 2004-10-26 |  | 0d |  | as late as possible |
| 86 | F.12.12.4.4.3 | MES伺服層 |  | 2d | 2004-10-22 | 2004-10-26 |  | 0d |  | as late as possible |
| 87 | F.12.12.5 | Integration Test |  | 5d | 2004-10-26 | 2004-11-02 | 79 | 0d |  | as late as possible |
| 88 | F.12.12.6 | 狀態確認 | milestone | 1d? | 2004-11-02 | 2004-11-03 | 87 | 0d |  | as late as possible |
| 89 | F.13 | **導入作業** |  | 99.5d? | 2004-10-11 | 2005-02-25 | 78 | 0d |  |  |
| 90 | F.13.12 | **功能測試作業** |  | 99.5d? | 2004-10-11 | 2005-02-25 | 78 | 0d |  |  |
| 91 | F.13.12.1 | **MES** |  | 25d? | 2005-01-24 | 2005-02-25 |  | 0d |  |  |
| 92 | F.13.12.1.1 | 測試劇本定義 |  | 5d | 2005-01-24 | 2005-01-28 |  | 4d | 0d | start no earlier than 2005-01-24 |
| 93 | F.13.12.1.2 | Ita 整合功能測試 |  | 5d | 2005-01-31 | 2005-02-04 | 92, 78 | 4d |  | start no earlier than 2005-01-31 |
| 94 | F.13.12.1.3 | ITb 整合功能測試 |  | 10d | 2005-02-11 | 2005-02-24 | 93 | 0d |  | start no earlier than 2005-02-11 |
| 95 | F.13.12.1.4 | 核准測試報告 |  | 1d? | 2005-02-25 | 2005-02-25 | 94 | 0d |  | start no earlier than 2005-02-25 |
| 96 | F.13.12.2 | **壓力測試(Stress Test)** |  | 23d? | 2004-10-11 | 2004-11-11 |  | 0d |  |  |
| 97 | F.13.12.2.1 | 測試計劃準備 |  | 7d | 2004-10-11 | 2004-10-20 |  | 0d |  | as late as possible |
| 98 | F.13.12.2.2 | **建置測試資料驅動系統** |  | 10d | 2004-10-20 | 2004-11-03 |  | 0d |  |  |
| 99 | F.13.12.2.2.1 | 程式撰寫 |  | 10d | 2004-10-20 | 2004-11-03 | 97 | 0d |  | as late as possible |
| 100 | F.13.12.2.2.2 | 程式安裝 |  | 2d | 2004-11-01 | 2004-11-03 |  | 0d |  | as late as possible |
| 101 | F.13.12.2.3 | 測試作業 |  | 3d | 2004-11-03 | 2004-11-08 | 88, 99 | 0d |  | as late as possible |
| 102 | F.13.12.2.4 | 遞交測試報告 |  | 2d | 2004-11-08 | 2004-11-10 | 101 | 0d |  | as late as possible |
| 103 | F.13.12.2.5 | 核准測試報告 | milestone | 1d? | 2004-11-10 | 2004-11-11 | 102 | 0d |  | as late as possible |
| 104 | F.13.12.3 | 即時接管機制測試(HACMP) |  | 2d | 2005-02-24 | 2005-02-25 |  | 0d |  | as late as possible |

| ID | WBS | Task | Type | Duration | Start | Finish | Predecessors | Total slack | Free slack | Constraint |
| --- | --- | --- | --- | --- | --- | --- | --- | --- | --- | --- |
| 105 | F.13.13 | **系統作業參數建置** |  | 1d? | 2004-10-11 | 2004-10-12 | 78 | 0d |  |  |
| 106 | F.13.13.1 | 建立資料工作表 |  | 1d? | 2004-10-11 | 2004-10-12 |  | 0d |  | as late as possible |
| 107 | F.13.13.2 | 資料收集與審核 |  | 1d? | 2004-10-11 | 2004-10-12 |  | 0d |  | as late as possible |
| 108 | F.13.13.3 | 系統輸入作業 |  | 1d? | 2004-10-11 | 2004-10-12 |  | 0d |  | as late as possible |
| 109 | F.13.13.4 | 資料驗證核准 |  | 1d? | 2004-10-11 | 2004-10-12 |  | 0d |  | as late as possible |
| 110 | F.13.14 | **教育訓練** |  | 33d? | 2005-01-12 | 2005-02-25 | 78 | 0d |  |  |
| 111 | F.13.14.1 | 教育訓練計劃提出 |  | 1d? | 2005-02-25 | 2005-02-25 |  | 0d |  | as late as possible |
| 112 | F.13.14.2 | 訓練教室準備 |  | 2d | 2005-01-12 | 2005-01-13 |  | 14d | 0d | start no earlier than 2005-01-12 |
| 113 | F.13.14.3 | 教材準備作業 |  | 5d | 2005-01-14 | 2005-01-20 | 112 | 14d | 0d |  |
| 114 | F.13.14.4 | 參與人員名冊準備 |  | 3d | 2005-01-21 | 2005-01-25 | 113 | 14d | 0d | start no earlier than 2005-01-21 |
| 115 | F.13.14.5 | **訓練執行** |  | 22d? | 2005-01-26 | 2005-02-24 | 114 | 0d |  |  |
| 116 | F.13.14.5.1 | 概念介紹 |  | 2d | 2005-02-15 | 2005-02-16 |  | 0d |  | as late as possible |
| 117 | F.13.14.5.2 | 主檔維護課程 |  | 1d? | 2005-01-26 | 2005-01-26 |  | 21d |  |  |
| 118 | F.13.14.5.3 | 設備管理操作課程 |  | 1d? | 2005-02-17 | 2005-02-17 | 116 | 5d |  |  |
| 119 | F.13.14.5.4 | SPC作業操作課程 |  | 1d? | 2005-02-22 | 2005-02-22 | 116 | 2d |  | start no earlier than 2005-02-22 |
| 120 | F.13.14.5.5 | **過帳作業操作課程** |  | 6d | 2005-02-17 | 2005-02-24 | 116 | 0d |  |  |
| 121 | F.13.14.5.5.1 | 工程師班 |  | 2d | 2005-02-17 | 2005-02-18 |  | 0d |  |  |
| 122 | F.13.14.5.5.2 | 作業員班 |  | 4d | 2005-02-21 | 2005-02-24 | 121 | 0d |  |  |
| 123 | F.13.14.6 | 訓練報告核准 |  | 1d? | 2005-02-25 | 2005-02-25 | 115 | 0d |  | start no earlier than 2005-02-25 |
| 124 | F.14 | 上線前準備作業 |  | 1d? | 2005-02-28 | 2005-02-28 | 91 | 0d |  | start no earlier than 2005-02-28 |
| 125 | F.15 | **結案作業** |  | 14d? | 2005-03-01 | 2005-03-18 |  | 0d |  |  |
| 126 | F.15.5 | 系統上線 | milestone | 0d? | 2005-03-01 | 2005-03-01 | 115, 64 | 0d |  | start no earlier than 2005-03-01 |
| 127 | F.15.6 | 使用者功能驗收 |  | 10d | 2005-03-01 | 2005-03-14 | 126 | 0d |  | as late as possible |
| 128 | F.15.7 | 結案報告 |  | 3d | 2005-03-15 | 2005-03-17 | 127 | 0d |  | as late as possible |
| 129 | F.15.8 | 結案會議 |  | 1d? | 2005-03-18 | 2005-03-18 | 128 | 0d |  | as late as possible |
